# Cronograma

Schedule from MS Project, 2022-03-16 to 2022-09-11, costs in S.

## Calendars

- Estándar: Mon-Sun 08:00-12:00, 13:00-17:00.

## Resources

| Resource | Group | Rate | Cost per use |
| --- | --- | --- | --- |
| OPERARIO | Mano de Obra | 23.8 |  |
| OFICIAL | Mano de Obra | 18.84 |  |
| PEON | Mano de Obra | 17.01 |  |
| OPERARIO TOPOGRAFO | Mano de Obra | 24.69 |  |
| CAPACITADOR | Mano de Obra | 1500 |  |
| ALAMBRE NEGRO #8 | Material |  | 3.34 |
| ALAMBRE NEGRO N° 16 | Material |  | 3.34 |
| ACERO CORRUGADO fy = 4200 kg/cm2 GRADO 60 | Material |  | 3.34 |
| REJILLA METALICA PARA RETENCION DE SOLIDOS | Material |  | 6 |
| ESTACA DE FIERRO CORRUGADO | Material |  | 3.37 |
| CLAVOS C/C DE 3" | Material |  | 3.56 |
| CLAVOS PARA CEMENTO DE 3/4" | Material |  | 3.56 |
| TEE 200x200MM PVC ISO 16422:2012 | Material |  | 350 |
| ABRAZADERA DE ALUMINIO FIJADAS AL CUERPO DEL BUZON CON TIRAFONES | Material |  | 150 |
| ABRAZADERA DE PVC 110MM | Material |  | 14.11 |
| ABRAZADERA DE PVC 160MM | Material |  | 22.57 |
| TUBERIA PVC UF NTP ISO 21138:2010 / 4435:2005 SN4 D=200 mm | Material |  | 24.54 |
| TUBERIA PVC UF NTP ISO 21138:2010 / 4435:2005 SN4 D=315 mm | Material |  | 61.65 |
| TUBERÍA PVC AGUA C-10 1/2" | Material |  | 1.68 |
| TUBERIA PVC SAL D= 2" | Material |  | 3.48 |
| TUBERIA PVC UF NTP ISO 21138:2010 / 4435:2005 SN4 D=160 mm | Material |  | 18.62 |
| CURVA PVC PARA AGUA DE 1/2" | Material |  | 1.73 |
| UNION PVC C-10 DE 1/2" | Material |  | 0.8 |
| CACHIMBA DE 160 MM X 200MM | Material |  | 49.24 |
| PIEDRA CHANCADA 1/2" | Material |  | 95 |
| PIEDRA GRANDE | Material |  | 35 |
| ARENA FINA | Material |  | 50 |
| ARENA GRUESA | Material |  | 50 |
| HORMIGON | Material |  | 52 |
| AFIRMADO | Material |  | 45 |
| AGUA PARA LA CONSTRUCCION | Material |  | 3500 |
| MARCO y TAPA TERMOPLASTICA PARA CAJA DE CONEXION DOMICIL. DE AGUA | Material |  | 45 |
| MARCO Y TAPA HDUCTIL P/ REGISTRO DE VALVULA | Material |  | 75 |
| MARCO FºFº Y PARA TAPA DE CONCRETO D=0.60M | Material |  | 265.05 |
| CODO 200MM/90º PVC ISO 4435 | Material |  | 55.08 |
| CODO DE 110MM X 45° PVC | Material |  | 46 |
| CODO DE 90° SP PVC SAP P/AGUA DE 1/2" | Material |  | 1.07 |
| CEMENTO PORTLAND TIPO V | Material |  | 28.05 |
| CEMENTO PORTLAND TIPO MS. | Material |  | 23.59 |
| YESO EN BOLSAS DE 18 kg | Material |  | 12.98 |
| LADRILLO ARCILLA KK 8.5x12x21 CM | Material |  | 0.3 |
| ADOQUIN DE CONCRETO DE 0.10X0.20X0.08 m. | Material |  | 55 |
| ALQUILER DE LOCAL P/OFICINAS Y ALMACEN | Material |  | 500 |
| TAPA DE CONCRETO ARMADO P/BUZON | Material |  | 84.75 |
| TUBERIA PVC-O UF PN8 D=110 mm NTP ISO 16422:2012. | Material |  | 15.66 |
| TUBERIA PVC-O UF PN8 D=160 mm NTP ISO 16422:2012. | Material |  | 33.02 |
| CORPORATION RT NIPLE TUERCA EMPAQUE 1/2" | Material |  | 6.81 |
| CAJA DE CONCRETO PREFABRICADA DE DESAGUE | Material |  | 75 |
| CAJA DE CONCRETO PARA MEDIDOR | Material |  | 24 |
| PEGAMENTO PARA PVC | Material |  | 50 |
| LUBRICANTE PARA TUBERIALUBRICANTE PARA TUBERIA | Material |  | 35 |
| IMPERMEABILIZANTE EN POLVO | Material |  | 5.46 |
| CURADOR MENBRANIL | Material |  | 11.84 |
| LOSA CON NICHO PARA MEDIDOR DE AGUA POTABLE 1/2" | Material |  | 15.5 |
| MADERA TORNILLO | Material |  | 6.5 |
| TRIPLAY DE 6mm | Material |  | 32.71 |
| PINTURA ESMALTE | Material |  | 38 |
| PINTURA ESMALTE PARA TRAFICO | Material |  | 35 |
| THINNER | Material |  | 17.01 |
| CINTA TEFLON | Material |  | 3.1 |
| CINTA SEÑALIZADORA COLOR AMARILLO | Material |  | 0.2 |
| ANILLO DE JEBE P/TUB. PVC - UF DN 200MM | Material |  | 5.22 |
| ANILLO DE JEBE P/TUB. PVC - UF DN315MM | Material |  | 19.58 |
| ANILLO DE JEBE P/TUB. PVC - UF DN 160MM | Material |  | 3.92 |
| CRUZ DE 160MM X 160MM PVC | Material |  | 447.27 |
| ANILLO DE JEBE P/TUB. PVC - UF DN 110MM | Material |  | 3.8 |
| CRUZ DE 110MM X 110MM PVC | Material |  | 143.6 |
| TEE DE 160 X 110 MM PVC C-10 | Material |  | 156 |
| TEE DE 110MM PVC | Material |  | 58.46 |
| MEDIDOR DE CHORRO MULTIPLE 1/2" PARA AGUA | Material |  | 90.67 |
| NIPLE PVC SAP A-10 1/2"X4" | Material |  | 1.75 |
| VALVULA COMPUERTA HD DE 6" | Material |  | 658.67 |
| VALVULA COMPUERTA HD DE 4" | Material |  | 424 |
| GRIFO CONTRAINCENDIO HIERRO DUCTIL TIPO POSTE 2 BOCAS DN 110MM | Material |  | 1680 |
| GRIFO CONTRAINCENDIO HIERRO DUCTIL TIPO POSTE 2 BOCAS DN 160MM | Material |  | 1700 |
| LLAVE DE PASO PVC 1/2" (INC.TUER-NIPLE) | Material |  | 5.56 |
| SPOTS RADIALES Y COMUNICADOS | Material |  | 100 |
| PARANTE DE MADERA CON BASE CONCRETO | Material |  | 12.71 |
| CASCOS CON CINTAS REFLECTIVAS | Material |  | 12.65 |
| CHALECO REFLECTIVO | Material |  | 42.3 |
| CONOS REFLECTANTES | Material |  | 22.45 |
| SEÑALIZACION PREVENTIVAS | Material |  | 40 |
| PLAN DE MONITOREO ARQUEOLOGICO | Material |  | 4000 |
| ANCLAJE DE SEGURIDAD | Material |  | 13.33 |
| AFERICION DE MEDIDORES | Material |  | 18 |
| PERNO 1/2X3" C/TUERCA | Material |  | 2.35 |
| HIPOCLORITO DE CALCIO AL 70% | Material |  | 75 |
| ESTROBOS | Material |  | 80 |
| ESLINGAS DE LONA | Material |  | 140 |
| RIEL TIPO PATIN " H " 4" x 4" x 1/4" (6m) | Material |  | 1650 |
| CILINDRO PARA AGUA | Material |  | 350 |
| AGUA | Material |  | 10 |
| BANNER | Material |  | 27.5 |
| BALDE PRUEBA TAPON ABRAZADERA Y ACCESORIOS | Material |  | 20 |
| IMPRESION Y FOTOCOPIADO DE MANUALES | Material |  | 300 |
| MATERIAL DIDACTICO PARA LOS TALLERES DE CAPACITACION | Material |  | 400 |
| ELABORACION Y DIAGRAMA DE MATERIAL DE SENSIBILIZACION Y CAPACITACION | Material |  | 500 |
| PROGRAMA DE MITIGACION | Material |  | 1200 |
| PROGRAMA DE MANEJO DE RESIDUOS SOLIDOS | Material |  | 1500 |
| PROGRAMA DE MONITOREO AMBIENTAL | Material |  | 2000 |
| PROGRAMA DE EDUCACION AMBIENTAL Y SENSIBILIZACION | Material |  | 1500 |
| CORDEL | Material |  | 0.3 |
| NIVEL TOPOGRAFICO | Equipo | 12.5 |  |
| TEODOLITO | Equipo | 15 |  |
| MIRAS | Equipo | 20 |  |
| JALONES | Equipo | 8 |  |
| ESCOFINA PLANA | Equipo | 23 |  |
| ENCOFRADO Y DESENCOFRADO METALICO | Equipo | 12 |  |
| BOMBA PARA PRUEBA DE AGUA | Equipo | 8 |  |
| MOTOBOMBA DE 4" (10 HP) | Equipo | 25 |  |
| COMPACTADORA VIBRATORIA TIPO PLANCHA 7 HP | Equipo | 18.5 |  |
| MARTILLO NEUMATICO DE 24 kg | Equipo | 80 |  |
| COMPRESORA NEUMATICA 700 - 800PCM 240 HP | Equipo | 30 |  |
| RADIO TRANSMISOR | Equipo | 150 |  |
| CARGADOR SOBRE LLANTAS DE 125-135 HP 2.5 yd3 | Equipo | 1720 |  |
| MINICARGADOR FRONTAL 64 HP | Equipo | 100 |  |
| EXCAVADORA S/ORUGA 195-225 HP 3.0 Y3. | Equipo | 265 |  |
| RETROEXCAVADORA SOBRE ORUGAS 115 - 165 HP | Equipo | 135 |  |
| MOTOFUMIGADORA 5.5 HP Q=30 L/min. | Equipo | 21 |  |
| CAMIONETA PICK UP | Equipo | 200 |  |
| CAMION VOLQUETE 6 X 4 330 HP 10 M3 | Equipo | 120 |  |
| CAMION CISTERNA 4X2(AGUA) 122HP 2000 gal | Equipo | 120 |  |
| VIBRADOR DE CONCRETO 4 HP 1.25" | Equipo | 10 |  |
| MEZCLADORA DE CONCRETO 11 P3 (23 HP) | Equipo | 35 |  |
| CIZALLA ELECTRICA DE FIERRO | Equipo | 5 |  |
| MOVILIZACION YDESMOVILZACION DE EQUIPOLIVIANO . | Equipo | 1602.45 |  |
| ZARANDA | Equipo | 10 |  |

## Schedule

| ID | WBS | Task | Type | Duration | Start | Finish | Predecessors | Total slack | Free slack | Constraint | Resources | Work | Cost | Text1 | Text8 | Text3 | Text4 | Text2 | Text6 |
| --- | --- | --- | --- | --- | --- | --- | --- | --- | --- | --- | --- | --- | --- | --- | --- | --- | --- | --- | --- |
| 1 | 1 | **RENOVACIÓN DE TUBERÍA DE PLÁSTICO PVC Y TUBERÍA DE PLÁSTICO PVC; EN EL(LA) A.P.V.M. LOS EDUCADORES EN LA LOCALIDAD PIURA, DISTRITO DE PIURA, PROVINCIA PIURA, DEPARTAMENTO PIURA** |  | 180d | 2022-03-16 | 2022-09-11 |  | 0d |  |  |  | 405989h | 4,235,477.15 |  |  |  |  |  |  |
| 2 | 1.1 | Inicio | milestone | 0d | 2022-03-16 | 2022-03-16 |  | 0d |  |  |  |  |  |  |  |  |  |  |  |
| 3 | 1.2 | **SISTEMA DE RED DE ALCANTARILLADO** |  | 180d | 2022-03-16 | 2022-09-11 |  | 0d |  |  |  | 35506.9h | 2,628,714.84 | 01 | 000000000000001 |  |  |  |  |
| 4 | 1.2.1 | **OBRAS PROVISIONALES** |  | 180d | 2022-03-16 | 2022-09-11 |  | 0d |  |  |  | 6287.02h | 61,349.05 | 01.01 | 000000000000002 |  |  |  |  |
| 5 | 1.2.1.1 | CARTEL DE IDENTIFICACION DE LA OBRA DE 7.20X3.60M |  | 1d | 2022-03-16 | 2022-03-16 | 6SS | 0d |  | start no earlier than 2021-03-01 | OPERARIO [200%]; PEON [200%]; ALAMBRE NEGRO N° 16 [300%]; CLAVOS C/C DE 3" [70%]; BANNER [2592%]; MADERA TORNILLO [7000%] | 32h | 1,947.81 | 01.01.01 | 000000000000023 | 1852.86 | 1852.86 |  |  |
| 6 | 1.2.1.2 | ALQUILER DE LOCAL PARA OFICINA Y ALMACEN |  | 180d | 2022-03-16 | 2022-09-11 | 2SS | 0d |  | start no earlier than 2021-03-01 | ALQUILER DE LOCAL P/OFICINAS Y ALMACEN [400%] | 5760h | 2,000 | 01.01.02 | 000000000000024 | 500 | 2000 |  |  |
| 7 | 1.2.1.3 | DEPOSITO PARA AGUA |  | 1d | 2022-03-16 | 2022-03-16 | 6SS | 178d | 0d | start no earlier than 2021-03-01 | CILINDRO PARA AGUA [300%] |  | 1,050 | 01.01.03 | 000000000000025 | 1050 | 1050 |  |  |
| 8 | 1.2.1.4 | AGUA PARA LA CONSTRUCCION |  | 1d | 2022-03-16 | 2022-03-17 | 7 | 178d |  | start no earlier than 2021-03-01 | AGUA PARA LA CONSTRUCCION |  | 3,500 | 01.01.04 | 000000000000086 | 3500 | 3500 |  |  |
| 9 | 1.2.1.5 | MOVILIZACION Y DESMOVILIZACION DE EQUIPOS |  | 1d | 2022-03-16 | 2022-03-16 | 2SS | 158d | 0d | start no earlier than 2021-03-01 | MOVILIZACION YDESMOVILZACION DE EQUIPOLIVIANO . [12.5%] | 1h | 3,500 | 01.01.05 | 000000000000026 | 1602.45 | 1602.45 |  |  |
| 10 | 1.2.1.6 | TRANQUERAS DE MADERA 1.20X1.10M P/DESVIO TRANSITO VEHICULAR |  | 5d | 2022-03-16 | 2022-03-20 | 6SS | 175d |  | start no earlier than 2021-03-01 | PINTURA ESMALTE PARA TRAFICO [80%]; OPERARIO; PEON [50%]; MADERA TORNILLO [45000%]; TRIPLAY DE 6mm [700%]; CLAVOS PARA CEMENTO DE 3/4" [200%] | 60h | 5,175.1 | 01.01.06 | 000000000000027 | 452.01 | 4520.1 | 10 |  |
| 11 | 1.2.1.7 | CINTA PLASTICA P/SEÑAL DE PELIGRO-LIMITE DE OBRA INC. POSTS 2"X2"X1.20 M. |  | 8d | 2022-03-16 | 2022-03-23 | 9SS | 158d | 0d | start no earlier than 2021-03-01 | OPERARIO [90.4%]; PEON [90.4%]; CINTA SEÑALIZADORA COLOR AMARILLO [906484%]; PARANTE DE MADERA CON BASE CONCRETO [43165.9%] | 115.68h | 9,514.15 | 01.01.07 | 000000000000028 | 1.13 | 9755.49 | 8633.18 | 1200 |
| 12 | 1.2.1.8 | MANTENIMIENTO DE TRANSITO VEHICULAR Y PEATONAL |  | 1d | 2022-03-16 | 2022-03-16 | 6SS | 179d |  | start no earlier than 2021-03-01 | RADIO TRANSMISOR [125%]; CAMIONETA PICK UP [187.5%]; PEON [3000%]; CASCOS CON CINTAS REFLECTIVAS [1000%]; CHALECO REFLECTIVO [1000%]; CONOS REFLECTANTES [2000%]; SEÑALIZACION PREVENTIVAS [2000%] | 265h | 10,320.9 | 01.01.08 | 000000000000029 | 10380.9 | 10380.9 |  |  |
| 13 | 1.2.1.9 | PUENTE PROVISIONAL DE MADERA |  | 2d | 2022-03-23 | 2022-03-25 | 11 | 170d |  | start no earlier than 2021-03-01 | PINTURA ESMALTE [330%]; THINNER [330%]; OPERARIO [83.3%]; PEON [250%]; CLAVOS C/C DE 3" [330%]; MADERA TORNILLO [36000%]; PERNO 1/2X3" C/TUERCA [6000%] | 53.33h | 4,226.6 | 01.01.09 | 000000000000030 | 370.18 | 3701.8 | 10 |  |
| 14 | 1.2.1.10 | IMPLEMENTACION DEL PLAN DE DESVIOS DE TRANSITO |  | 1d | 2022-03-17 | 2022-03-17 | 5 | 176d | 0d |  |  |  | 20,114.49 | 01.01.10 |  |  |  |  |  |
| 15 | 1.2.2 | **TRABAJOS PRELIMINARES** |  | 49d | 2022-03-16 | 2022-05-03 |  | 0d |  |  |  | 2555.23h | 138,636.01 | 01.02 | 000000000000003 |  |  |  |  |
| 16 | 1.2.2.1 | TRAZO Y REPLANTEO DE OBRA |  | 9d | 2022-03-16 | 2022-03-24 | 6SS | 0d |  | start no earlier than 2021-03-01 | YESO EN BOLSAS DE 18 kg [21583%]; MIRAS [12%]; JALONES [12%]; PINTURA ESMALTE [4316.6%]; PEON [191.8%]; OPERARIO TOPOGRAFO [95.9%]; NIVEL TOPOGRAFICO [95.9%]; TEODOLITO [95.9%]; ESTACA DE FIERRO CORRUGADO [17266.4%]; CORDEL [43165.9%] | 362.59h | 11,282.26 | 01.02.01 | 000000000000032 | 2.66 | 11482.13 | 4316.59 | 500 |
| 17 | 1.2.2.2 | EXTRACCION Y ELIMINACION DE TUBERIA EXISTENTE |  | 10d | 2022-04-08 | 2022-04-17 | 26 | 147d |  | start no earlier than 2021-03-01 | PEON [490.5%]; RETROEXCAVADORA SOBRE ORUGAS 115 - 165 HP [98.1%] | 470.9h | 41,466.53 | 01.02.02 | 000000000000033 | 8.9 | 38417.65 | 4316.59 | 200 |
| 18 | 1.2.2.3 | REMOCION DE CONEXIONES DOMICILIARIAS DE DESAGUE EXISTENTE |  | 10d | 2022-04-02 | 2022-04-11 | 21 | 153d |  | start no earlier than 2021-03-01 | PEON [200%] | 160h | 31,763 | 01.02.03 | 000000000000034 | 70.08 | 32236.8 | 460 |  |
| 19 | 1.2.2.4 | DEMOLICION DE BUZON EXISTENTE |  | 17d | 2022-04-08 | 2022-04-24 | 26 | 131d | 0d | start no earlier than 2021-03-01 | OFICIAL [194.1%]; PEON [388.2%]; MARTILLO NEUMATICO DE 24 kg [97.1%]; COMPRESORA NEUMATICA 700 - 800PCM 240 HP [194.1%] | 1188h | 44,295.9 | 01.02.04 | 000000000000035 | 497.78 | 32853.48 | 66 |  |
| 20 | 1.2.2.5 | TRASVASE DE AGUAS SERVIDAS A BUZONES |  | 9d | 2022-04-25 | 2022-05-03 | 19 | 131d |  | start no earlier than 2021-03-01 | OFICIAL; MOTOBOMBA DE 4" (10 HP) | 144h | 3,174.48 | 01.02.05 | 000000000000036 | 44.41 | 3197.52 | 72 |  |
| 21 | 1.2.2.6 | DEMOLICION DE VEREDAS PARA CONEXIONES DOMICILIARIA |  | 8d | 2022-03-25 | 2022-04-01 | 16 | 33d | 0d | start no earlier than 2021-03-01 | OPERARIO [48.3%]; PEON [96.6%] | 92.74h | 1,816.08 | 01.02.06 | 000000000000037 | 2.38 | 1839.26 | 772.8 | 100 |
| 22 | 1.2.2.7 | DEMOLICION DE PAVIMENTO DE ADOQUIN |  | 2d | 2022-04-02 | 2022-04-03 | 21 | 33d | 0d | start no earlier than 2021-03-01 | OPERARIO [169.2%]; PEON [338.5%]; MARTILLO NEUMATICO DE 24 kg [84.6%]; COMPRESORA NEUMATICA 700 - 800PCM 240 HP [84.6%] | 108.31h | 3,824.6 | 01.02.07 | 000000000000090 | 9.16 | 3100.29 | 338.46 | 200 |
| 23 | 1.2.2.8 | DEMOLICION DE LOSA DE CONCRETO |  | 1d | 2022-04-04 | 2022-04-04 | 22 | 33d | 0d | start no earlier than 2021-03-01 | OPERARIO [89.7%]; PEON [179.3%]; MARTILLO NEUMATICO DE 24 kg [44.8%]; COMPRESORA NEUMATICA 700 - 800PCM 240 HP [44.8%] | 28.69h | 1,013.16 | 01.02.08 | 000000000000100 | 9.16 | 821.29 | 89.66 | 200 |
| 24 | 1.2.3 | **MOVIMIENTO DE TIERRAS** |  | 126d | 2022-04-05 | 2022-08-08 |  | 33d |  |  |  | 7870.06h | 944,343.84 | 01.03 | 000000000000004 |  |  |  |  |
| 25 | 1.2.3.1 | **EXCAVACIONES** |  | 46d | 2022-04-05 | 2022-05-20 |  | 33d |  |  |  | 821.72h | 102,011.72 | 01.03.01 | 000000000000005 |  |  |  |  |
| 26 | 1.2.3.1.1 | EXCAVACION PARA BUZONES HASTA H=2.00 |  | 3d | 2022-04-05 | 2022-04-07 | 23 | 33d | 0d | start no earlier than 2021-03-01 | PEON [195.5%]; RETROEXCAVADORA SOBRE ORUGAS 115 - 165 HP [97.7%] | 70.37h | 3,192.91 | 01.03.01.01 | 000000000000038 | 34 | 3987.52 | 117.28 | 40 |
| 27 | 1.2.3.1.2 | EXCAVACION PARA BUZONES PARA H>2.00 |  | 3d | 2022-04-08 | 2022-04-10 | 26 | 154d |  | start no earlier than 2021-03-01 | PEON [139.7%]; EXCAVADORA S/ORUGA 195-225 HP 3.0 Y3. [69.8%] | 50.29h | 5,471.83 | 01.03.01.02 | 000000000000039 | 40 | 5028.8 | 125.72 | 60 |
| 28 | 1.2.3.1.3 | EXCAVACIÓN C/EQUIPO ALCANTARILLADO HPROM <=1.50M |  | 15d | 2022-04-05 | 2022-04-19 | 26SS | 33d | 0d | start no earlier than 2021-03-01 | PEON [96.8%]; RETROEXCAVADORA SOBRE ORUGAS 115 - 165 HP [96.8%] | 232.23h | 16,148.48 | 01.03.01.03 | 000000000000041 | 10.16 | 20045.68 | 1973 | 120 |
| 29 | 1.2.3.1.4 | EXCAVACIÓN C/EQUIPO ALCANTARILLADO HPROM=1.51M A 2.00M |  | 10d | 2022-04-20 | 2022-04-29 | 28 | 67d | 0d | start no earlier than 2021-03-01 | PEON [92.9%]; EXCAVADORA S/ORUGA 195-225 HP 3.0 Y3. [92.9%] | 148.64h | 20,722.98 | 01.03.01.04 | 000000000000040 | 20.55 | 21008.47 | 1022.31 | 110 |
| 30 | 1.2.3.1.5 | EXCAVACIÓN C/EQUIPO ALCANTARILLADO HPROM=2.01M A 2.50M |  | 4d | 2022-04-30 | 2022-05-03 | 29 | 67d | 0d | start no earlier than 2021-03-01 | PEON [91.5%]; EXCAVADORA S/ORUGA 195-225 HP 3.0 Y3. [91.5%] | 58.57h | 21,148.36 | 01.03.01.05 | 000000000000091 | 25.12 | 8274.78 | 329.41 | 90 |
| 31 | 1.2.3.1.6 | EXCAVACIÓN C/EQUIPO ALCANTARILLADO HPROM=2.51M A 3.00M |  | 4d | 2022-05-04 | 2022-05-07 | 30 | 127d |  | start no earlier than 2021-03-01 | PEON [84.5%]; EXCAVADORA S/ORUGA 195-225 HP 3.0 Y3. [84.5%] | 54.11h | 9,818.39 | 01.03.01.06 | 000000000000092 | 28.25 | 7642.47 | 270.53 | 80 |
| 32 | 1.2.3.1.7 | EXCAVACIÓN C/EQUIPO ALCANTARILLADO HPROM=3.01M A 3.50M |  | 3d | 2022-04-30 | 2022-05-02 | 29 | 111d | 0d | start no earlier than 2021-03-01 | PEON [90.6%]; EXCAVADORA S/ORUGA 195-225 HP 3.0 Y3. [90.6%] | 43.5h | 8,780.67 | 01.03.01.07 | 000000000000042 | 32.29 | 6144.79 | 190.3 | 70 |
| 33 | 1.2.3.1.8 | EXCAVACIÓN C/EQUIPO ALCANTARILLADO HPROM=3.51M A 4.00M |  | 4d | 2022-05-03 | 2022-05-06 | 32 | 111d | 0d | start no earlier than 2021-03-01 | PEON [92.9%]; EXCAVADORA S/ORUGA 195-225 HP 3.0 Y3. [92.9%] | 59.43h | 5,864.8 | 01.03.01.08 | 000000000000043 | 41.1 | 8393.03 | 204.21 | 55 |
| 34 | 1.2.3.1.9 | EXCAVACIÓN C/EQUIPO ALCANTARILLADO HPROM=4.01M A 4.50M |  | 7d | 2022-05-07 | 2022-05-13 | 33 | 111d | 0d | start no earlier than 2021-03-01 | PEON [93.4%]; EXCAVADORA S/ORUGA 195-225 HP 3.0 Y3. [93.4%] | 104.59h | 5,477.91 | 01.03.01.09 | 000000000000102 | 45.2 | 14772.72 | 326.83 | 50 |
| 35 | 1.2.3.1.10 | EXCAVACIÓN C/EQUIPO ALCANTARILLADO HPROM=4.51M A 5.00M |  | 7d | 2022-05-14 | 2022-05-20 | 34 | 111d | 0d |  |  |  | 5,385.39 | 01.03.01.10 |  |  |  |  |  |

| ID | WBS | Task | Duration | Start | Finish | Predecessors | Total slack | Free slack | Constraint | Resources | Work | Cost | Text1 | Text8 | Text2 | Text3 | Text4 | Text6 |
| --- | --- | --- | --- | --- | --- | --- | --- | --- | --- | --- | --- | --- | --- | --- | --- | --- | --- | --- |
| 36 | 1.2.3.2 | **REFINE, NIVELACIÓN DE FONDO DE ZANJA** | 34d | 2022-04-20 | 2022-05-23 |  | 33d |  |  |  | 423.74h | 20,289.82 | 01.03.02 | 000000000000006 |  |  |  |  |
| 37 | 1.2.3.2.1 | REFINE Y NIVELACION EN TERRENO NORMAL HASTA H=1.50 M | 15d | 2022-04-20 | 2022-05-04 | 28 | 38d | 0d | start no earlier than 2021-03-01 | PEON [193.4%] | 232.06h | 3,142.26 | 01.03.02.01 | 000000000000045 | 1973 | 2.34 | 4616.82 | 120 |
| 38 | 1.2.3.2.2 | REFINE Y NIVELACION EN TERRENO NORMAL HASTA H=2.00 M | 3d | 2022-05-04 | 2022-05-06 | 30 | 72d | 0d | start no earlier than 2021-03-01 | PEON [170.4%]; RETROEXCAVADORA SOBRE ORUGAS 115 - 165 HP [85.2%] | 61.34h | 3,926.57 | 01.03.02.02 | 000000000000046 | 1022.31 | 3.4 | 3475.85 | 400 |
| 39 | 1.2.3.2.3 | REFINE Y NIVELACION EN TERRENO NORMAL HASTA H=2.50 M | 1d | 2022-05-07 | 2022-05-07 | 38 | 72d | 0d | start no earlier than 2021-03-01 | PEON [164.7%]; RETROEXCAVADORA SOBRE ORUGAS 115 - 165 HP [82.4%] | 19.76h | 3,278.88 | 01.03.02.03 | 000000000000093 | 329.41 | 3.4 | 1119.99 | 400 |
| 40 | 1.2.3.2.4 | REFINE Y NIVELACION EN TERRENO NORMAL HASTA H=3.00 M | 1d | 2022-05-03 | 2022-05-03 | 32 | 130d | 0d | start no earlier than 2021-03-01 | PEON [154.5%]; RETROEXCAVADORA SOBRE ORUGAS 115 - 165 HP [77.4%] | 18.56h | 1,547.71 | 01.03.02.04 | 000000000000103 | 270.53 | 3.89 | 1052.36 | 350 |
| 41 | 1.2.3.2.5 | REFINE Y NIVELACION EN TERRENO NORMAL HASTA H=3.50 M | 1d | 2022-05-04 | 2022-05-04 | 40 | 130d |  | start no earlier than 2021-03-01 | PEON [126.8%]; EXCAVADORA S/ORUGA 195-225 HP 3.0 Y3. [63.5%] | 15.22h | 2,176.8 | 01.03.02.05 | 000000000000047 | 190.3 | 8.02 | 1526.21 | 300 |
| 42 | 1.2.3.2.6 | REFINE Y NIVELACION EN TERRENO NORMAL HASTA H=4.00 M | 2d | 2022-05-14 | 2022-05-15 | 34 | 116d | 0d | start no earlier than 2021-03-01 | PEON [102.1%]; EXCAVADORA S/ORUGA 195-225 HP 3.0 Y3. [51.1%] | 24.51h | 1,710.74 | 01.03.02.06 | 000000000000048 | 204.21 | 12 | 2450.52 | 200 |
| 43 | 1.2.3.2.7 | REFINE Y NIVELACION EN TERRENO NORMAL HASTA H=4.50 M | 3d | 2022-05-16 | 2022-05-18 | 42 | 116d |  | start no earlier than 2021-03-01 | PEON [145.3%]; EXCAVADORA S/ORUGA 195-225 HP 3.0 Y3. [72.6%] | 52.29h | 1,935.95 | 01.03.02.07 | 000000000000049 | 326.83 | 15.98 | 5222.74 | 150 |
| 44 | 1.2.3.2.8 | REFINE Y NIVELACION EN TERRENO NORMAL HASTA H=5.00 M | 3d | 2022-05-21 | 2022-05-23 | 35 | 111d |  |  |  |  | 2,570.91 | 01.03.02.08 |  |  |  |  |  |
| 45 | 1.2.3.3 | **CAMA DE APOYO** | 27d | 2022-05-04 | 2022-05-31 |  | 33d |  |  |  | 808.91h | 82,373.89 | 01.03.03 | 000000000000007 |  |  |  |  |
| 46 | 1.2.3.3.1 | CAMA DE APOYO CON MATERIAL DE PRESTAMO E=15cm, HASTA H=3.00 | 20d | 2022-05-04 | 2022-05-24 | 37 | 33d | 0d | start no earlier than 2021-03-01 | OFICIAL [97.7%]; PEON [195.4%]; RETROEXCAVADORA SOBRE ORUGAS 115 - 165 HP [97.7%]; AFIRMADO [67410.9%] | 625.26h | 68,223.32 | 01.03.03.01 | 000000000000050 | 3595.25 | 17.91 | 64390.93 | 160 |
| 47 | 1.2.3.3.2 | CAMA DE APOYO CON MATERIAL DE PRESTAMO E=15cm, HASTA H=5.50 | 7d | 2022-05-24 | 2022-05-31 | 46 | 103d |  | start no earlier than 2021-03-01 | OFICIAL [93.6%]; PEON [187.4%]; EXCAVADORA S/ORUGA 195-225 HP 3.0 Y3. [46.9%]; AFIRMADO [13525.1%] | 183.65h | 14,150.57 | 01.03.03.02 | 000000000000051 | 721.34 | 22.05 | 15905.55 | 110 |
| 48 | 1.2.3.4 | **RELLENO Y COMPACTADO DE ZANJAS** | 47d | 2022-06-19 | 2022-08-05 |  | 33d |  |  |  | 3230.05h | 168,023.29 | 01.03.04 | 000000000000008 |  |  |  |  |
| 49 | 1.2.3.4.1 | RELLENO PROTECTOR C/MAT. PROPIO ZARANDEADO HASTA H=0.30M,S/CLAVE TUB. DESAG. HASTA H<3.00 | 30d | 2022-06-19 | 2022-07-19 | 72 | 33d | 0d | start no earlier than 2021-03-01 | OPERARIO; PEON [399.5%]; COMPACTADORA VIBRATORIA TIPO PLANCHA 7 HP; RETROEXCAVADORA SOBRE ORUGAS 115 - 165 HP [49.9%]; ZARANDA [199.7%]; AGUA [89881.2%] | 2037.31h | 69,328.87 | 01.03.04.01 | 000000000000057 | 3595.25 | 18.54 | 66655.94 | 100 |
| 50 | 1.2.3.4.2 | RELLENO PROTECTOR C/MAT. PROPIO ZARANDEADO HASTA H=0.30M,S/CLAVE TUB. DESAG. HASTA H>3.00 | 9d | 2022-07-19 | 2022-07-28 | 49 | 45d |  | start no earlier than 2021-03-01 | OPERARIO [89.1%]; PEON [356.3%]; COMPACTADORA VIBRATORIA TIPO PLANCHA 7 HP [89.1%]; EXCAVADORA S/ORUGA 195-225 HP 3.0 Y3. [44.5%]; ZARANDA [178.1%]; AGUA [18033.5%] | 545.04h | 16,711.7 | 01.03.04.02 | 000000000000058 | 721.34 | 26.11 | 18834.19 | 90 |
| 51 | 1.2.3.4.3 | RELLENO COMPACT. C/MAT. PROPIO T. NORMAL, HASTA 1.50M | 5d | 2022-07-19 | 2022-07-24 | 49 | 33d | 0d | start no earlier than 2021-03-01 | OPERARIO [98.7%]; PEON [295.9%]; COMPACTADORA VIBRATORIA TIPO PLANCHA 7 HP [98.7%]; CAMION CISTERNA 4X2(AGUA) 122HP 2000 gal [49.3%]; AGUA [197300%] | 217.03h | 17,883.56 | 01.03.04.03 | 000000000000052 | 1973 | 13.12 | 25885.76 | 400 |
| 52 | 1.2.3.4.4 | RELLENO COMPACT. C/MAT. PROPIO T. NORMAL, HASTA 2.00M | 3d | 2022-07-24 | 2022-07-27 | 51 | 33d | 0d | start no earlier than 2021-03-01 | OPERARIO [85.2%]; PEON [255.6%]; COMPACTADORA VIBRATORIA TIPO PLANCHA 7 HP [85.2%]; MINICARGADOR FRONTAL 64 HP [85.2%]; CAMION CISTERNA 4X2(AGUA) 122HP 2000 gal [42.6%]; AGUA [122677%] | 132.9h | 17,250.65 | 01.03.04.04 | 000000000000053 | 1022.31 | 17.12 | 17501.95 | 400 |
| 53 | 1.2.3.4.5 | RELLENO COMPACT. C/MAT. PROPIO T. NORMAL, HASTA 2.50M | 1d | 2022-07-27 | 2022-07-28 | 52 | 44d | 0d | start no earlier than 2021-03-01 | OPERARIO [82.4%]; PEON [247.1%]; COMPACTADORA VIBRATORIA TIPO PLANCHA 7 HP [82.4%]; MINICARGADOR FRONTAL 64 HP [82.4%]; CAMION CISTERNA 4X2(AGUA) 122HP 2000 gal [41.2%]; AGUA [46117.4%] | 42.82h | 16,090.96 | 01.03.04.05 | 000000000000094 | 329.41 | 19.12 | 6298.32 | 400 |
| 54 | 1.2.3.4.6 | RELLENO COMPACT. C/MAT. PROPIO T. NORMAL, HASTA 3.00M | 1d | 2022-07-28 | 2022-07-29 | 53 | 44d |  | start no earlier than 2021-03-01 | OPERARIO [77.4%]; PEON [232%]; COMPACTADORA VIBRATORIA TIPO PLANCHA 7 HP [77.4%]; MINICARGADOR FRONTAL 64 HP [77.4%]; CAMION CISTERNA 4X2(AGUA) 122HP 2000 gal [38.5%]; AGUA [43284.8%] | 40.23h | 7,589 | 01.03.04.06 | 000000000000095 | 270.53 | 21.85 | 5911.08 | 350 |
| 55 | 1.2.3.4.7 | RELLENO COMPACT. C/MAT. PROPIO T. NORMAL, HASTA 3.50M | 1d | 2022-07-27 | 2022-07-28 | 52 | 33d | 0d | start no earlier than 2021-03-01 | OPERARIO [63.5%]; PEON [190.3%]; COMPACTADORA VIBRATORIA TIPO PLANCHA 7 HP [63.5%]; MINICARGADOR FRONTAL 64 HP [63.5%]; EXCAVADORA S/ORUGA 195-225 HP 3.0 Y3. [31.6%]; CAMION CISTERNA 4X2(AGUA) 122HP 2000 gal [31.6%]; AGUA [34254%] | 35.53h | 7,703.15 | 01.03.04.07 | 000000000000054 | 190.3 | 28.34 | 5393.1 | 300 |
| 56 | 1.2.3.4.8 | RELLENO COMPACT. C/MAT. PROPIO T. NORMAL, HASTA 4.00M | 2d | 2022-07-28 | 2022-07-30 | 55 | 34d | 0d | start no earlier than 2021-03-01 | OPERARIO [51.1%]; PEON [153.2%]; COMPACTADORA VIBRATORIA TIPO PLANCHA 7 HP [51.1%]; MINICARGADOR FRONTAL 64 HP [51.1%]; EXCAVADORA S/ORUGA 195-225 HP 3.0 Y3. [25.5%]; CAMION CISTERNA 4X2(AGUA) 122HP 2000 gal [25.5%]; AGUA [40842%] | 57.18h | 5,066.54 | 01.03.04.08 | 000000000000055 | 204.21 | 35.52 | 7253.54 | 200 |
| 57 | 1.2.3.4.9 | RELLENO COMPACT. C/MAT. PROPIO T. NORMAL, HASTA 4.50M | 3d | 2022-07-30 | 2022-08-02 | 56 | 34d | 0d | start no earlier than 2021-03-01 | OPERARIO [72.6%]; PEON [217.9%]; COMPACTADORA VIBRATORIA TIPO PLANCHA 7 HP [72.6%]; MINICARGADOR FRONTAL 64 HP [72.6%]; EXCAVADORA S/ORUGA 195-225 HP 3.0 Y3. [36.4%]; CAMION CISTERNA 4X2(AGUA) 122HP 2000 gal [36.4%]; AGUA [65366%] | 122.01h | 4,930.85 | 01.03.04.09 | 000000000000104 | 326.83 | 40.71 | 13305.25 | 150 |
| 58 | 1.2.3.4.10 | RELLENO COMPACT. C/MAT. PROPIO T. NORMAL, HASTA 5.00M | 3d | 2022-08-03 | 2022-08-05 | 57 | 39d | 0d |  |  |  | 5,468.01 | 01.03.04.10 |  |  |  |  |  |
| 59 | 1.2.3.5 | **ELIMINACIÓN DE MATERIAL EXCEDENTE** | 3d | 2022-08-06 | 2022-08-08 |  | 34d |  |  |  | 146.09h | 16,885.95 | 01.03.05 | 000000000000009 |  |  |  |  |
| 60 | 1.2.3.5.1 | ELIMINACION DE MATERIAL DE EXCEDENTE Dp=5KM | 3d | 2022-08-06 | 2022-08-08 | 58 | 39d |  | start no earlier than 2021-03-01 | CARGADOR SOBRE LLANTAS DE 125-135 HP 2.5 yd3 [12.7%]; PEON [198.4%]; CAMION VOLQUETE 6 X 4 330 HP 10 M3 [397.5%] | 146.09h | 16,885.95 | 01.03.05.01 | 000000000000059 | 1608.88 | 10.91 | 17552.88 | 540 |

| ID | WBS | Task | Duration | Start | Finish | Predecessors | Total slack | Free slack | Constraint | Resources | Work | Cost | Text1 | Text8 | Text2 | Text3 | Text4 | Text6 |
| --- | --- | --- | --- | --- | --- | --- | --- | --- | --- | --- | --- | --- | --- | --- | --- | --- | --- | --- |
| 61 | 1.2.3.6 | **ENTIBADO Y PROTECCION DE ZANJAS** | 60d | 2022-05-07 | 2022-07-06 |  | 67d |  |  |  | 2439.55h | 554,759.17 | 01.03.06 | 000000000000010 |  |  |  |  |
| 62 | 1.2.3.6.1 | ENTIBADO Y DESENTIBADO DE MADERA DESDE H=2.00M A 2.50M | 30d | 2022-05-07 | 2022-06-06 | 39 | 67d | 0d | start no earlier than 2021-03-01 | OPERARIO [187.8%]; PEON [281.6%]; RETROEXCAVADORA SOBRE ORUGAS 115 - 165 HP [93.9%]; ALAMBRE NEGRO #8 [40551.6%]; ALAMBRE NEGRO N° 16 [81103.2%]; MADERA TORNILLO; ESTROBOS [2703.4%]; ESLINGAS DE LONA [2703.4%] | 1351.89h | 259,544.28 | 01.03.06.01 | 000000000000060 | 1351.72 | 117.48 | 158800.07 | 90 |
| 63 | 1.2.3.6.2 | ENTIBADO Y DESENTIBADO DE MADERA DESDE H=2.50M A 3.50M | 10d | 2022-06-06 | 2022-06-16 | 62 | 67d | 0d | start no earlier than 2021-03-01 | OPERARIO [192%]; PEON [384%]; EXCAVADORA S/ORUGA 195-225 HP 3.0 Y3. [96%]; ALAMBRE NEGRO #8 [13824.9%]; ALAMBRE NEGRO N° 16 [27649.8%]; MADERA TORNILLO; ESTROBOS [921.7%]; ESLINGAS DE LONA [921.7%] | 537.63h | 136,297.41 | 01.03.06.02 | 000000000000061 | 460.83 | 187.38 | 86350.33 | 80 |
| 64 | 1.2.3.6.3 | ENTIBADO Y DESENTIBADO DE MADERA DESDE H=3.50M A 4.50M | 10d | 2022-06-16 | 2022-06-26 | 63 | 67d | 0d | start no earlier than 2021-03-01 | OPERARIO [189.7%]; PEON [379.3%]; EXCAVADORA S/ORUGA 195-225 HP 3.0 Y3. [94.8%]; RETROEXCAVADORA SOBRE ORUGAS 115 - 165 HP [23.7%]; ALAMBRE NEGRO #8 [15931.2%]; ALAMBRE NEGRO N° 16 [31862.4%]; MADERA TORNILLO; ESTROBOS [1062.1%]; ESLINGAS DE LONA [1062.1%]; RIEL TIPO PATIN " H " 4" x 4" x 1/4" (6m) [3717.3%] | 550.02h | 106,881.27 | 01.03.06.03 | 000000000000062 | 531.04 | 360.41 | 191392.13 | 70 |
| 65 | 1.2.3.6.4 | ENTIBADO Y DESENTIBADO DE MADERA DESDE H=4.50M A 5.50M | 10d | 2022-06-27 | 2022-07-06 | 64 | 72d |  |  |  |  | 52,036.21 | 01.03.06.04 |  |  |  |  |  |
| 66 | 1.2.4 | **SUMINISTRO E INSTALACIÓN DE TUBERIAS DE PVC NTP ISO 21138:2010 /4435:2005** | 48d | 2022-05-04 | 2022-06-21 |  | 33d |  |  |  | 1968.66h | 335,991.29 | 01.04 | 000000000000011 |  |  |  |  |
| 67 | 1.2.4.1 | **SUMINISTRO TUBERIA DE ALCANTARILLADO PVC NTP ISO 21138:2010 /4435:2005** | 2d | 2022-05-04 | 2022-05-06 |  | 33d |  |  |  |  | 278,843.07 | 01.04.01 | 000000000000012 |  |  |  |  |
| 68 | 1.2.4.1.1 | SUMINISTRO DE TUBERIA PVC UF NTP ISO 21138:2010 / 4435:2005 SN4 D=200 mm | 1d | 2022-05-04 | 2022-05-05 | 46SS | 33d | 0d | start no earlier than 2021-03-01 | LUBRICANTE PARA TUBERIALUBRICANTE PARA TUBERIA [22264%]; TUBERIA PVC UF NTP ISO 21138:2010 / 4435:2005 SN4 D=200 mm [389620%]; ANILLO DE JEBE P/TUB. PVC - UF DN 200MM [61856.9%] |  | 207,319.34 | 01.04.01.01 | 000000000000063 | 3710.67 | 28.74 | 106644.66 |  |
| 69 | 1.2.4.1.2 | SUMINISTRO DE TUBERIA PVC UF NTP ISO 21138:2010 / 4435:2005 SN4 D=315 mm | 1d | 2022-05-05 | 2022-05-06 | 68 | 128d |  | start no earlier than 2021-03-01 | LUBRICANTE PARA TUBERIALUBRICANTE PARA TUBERIA [3635.5%]; TUBERIA PVC UF NTP ISO 21138:2010 / 4435:2005 SN4 D=315 mm [63621.6%]; ANILLO DE JEBE P/TUB. PVC - UF DN315MM [10100.7%] |  | 71,523.73 | 01.04.01.02 | 000000000000105 | 605.92 | 70.09 | 42468.93 |  |
| 70 | 1.2.4.2 | **INSTALACION DE TUBERIAS DE PVC NTP ISO 21138:2010 / 4435:2005** | 45d | 2022-05-06 | 2022-06-19 |  | 33d |  |  |  | 1761.44h | 29,523.92 | 01.04.02 | 000000000000022 |  |  |  |  |
| 71 | 1.2.4.2.1 | INST. DE TUBERIA PVC DESAGUE U.F. NTP ISO 21138:2010 / 4435:2005 SN4 DN 200MM | 37d | 2022-05-06 | 2022-06-11 | 68 | 38d | 0d | start no earlier than 2021-03-01 | OPERARIO [199.4%]; PEON [300%] | 1478.35h | 24,600.96 | 01.04.02.01 | 000000000000065 | 3710.67 | 6.78 | 25158.34 | 120 |
| 72 | 1.2.4.2.2 | INST. DE TUBERIA PVC DESAGUE U.F. NTP ISO 21138:2010 / 4435:2005 SN4 DN 315MM | 8d | 2022-06-12 | 2022-06-19 | 71 | 38d | 0d | start no earlier than 2021-03-01 | OPERARIO [189.3%]; PEON [253%] | 283.09h | 4,922.96 | 01.04.02.02 | 000000000000106 | 605.92 | 9.58 | 5804.71 | 80 |
| 73 | 1.2.4.3 | **PRUEBA HIDRAULICA + ESCORRENTIA** | 10d | 2022-06-11 | 2022-06-21 |  | 82d |  |  |  | 207.22h | 27,624.3 | 01.04.03 | 000000000000013 |  |  |  |  |
| 74 | 1.2.4.3.1 | PRUEBA HIDRAULICA + ESCORRENTIA PARA TUBERIA DE DESAGUE DN 200MM | 7d | 2022-06-11 | 2022-06-18 | 71 | 85d |  | start no earlier than 2021-03-01 | CEMENTO PORTLAND TIPO MS. [25974.7%]; YESO EN BOLSAS DE 18 kg [55660.1%]; OPERARIO [88.1%]; PEON [176.9%]; CAMION CISTERNA 4X2(AGUA) 122HP 2000 gal [44.4%]; AGUA [31169.6%]; LADRILLO ARCILLA KK 8.5x12x21 CM [92766.8%] | 173.29h | 22,941.23 | 01.04.03.01 | 000000000000067 | 3710.67 | 6.11 | 22672.19 | 600 |
| 75 | 1.2.4.3.2 | PRUEBA HIDRAULICA + ESCORRENTIA PARA TUBERIA DE DESAGUE DN 315MM | 2d | 2022-06-19 | 2022-06-21 | 72 | 82d |  | start no earlier than 2021-03-01 | CEMENTO PORTLAND TIPO MS. [6059.2%]; YESO EN BOLSAS DE 18 kg [12118.4%]; OPERARIO [60.6%]; PEON [121.2%]; CAMION CISTERNA 4X2(AGUA) 122HP 2000 gal [30.3%]; AGUA [11258%]; LADRILLO ARCILLA KK 8.5x12x21 CM [15148%] | 33.93h | 4,683.07 | 01.04.03.02 | 000000000000107 | 605.92 | 8.81 | 5338.16 | 500 |
| 76 | 1.2.5 | **BUZONES, TAPONES Y EMPALMES** | 87d | 2022-04-07 | 2022-07-03 |  | 70d |  |  |  | 7446.6h | 300,118.41 | 01.05 | 000000000000014 |  |  |  |  |
| 77 | 1.2.5.1 | **SOLADO PARA BUZONES** | 4d | 2022-04-07 | 2022-04-11 |  | 70d |  |  |  | 126.81h | 6,010.71 | 01.05.01 | 000000000000015 |  |  |  |  |
| 78 | 1.2.5.1.1 | BASE COMPACTADA CON MATERIAL DE PRESTAMO E=0.40m | 1d | 2022-04-07 | 2022-04-08 | 26 | 70d | 0d | start no earlier than 2021-03-01 | OFICIAL [36.9%]; PEON [73.7%]; COMPACTADORA VIBRATORIA TIPO PLANCHA 7 HP [36.9%]; AFIRMADO [1106%]; AGUA [44.2%] | 11.8h | 1,429.51 | 01.05.01.01 | 000000000000126 | 22.12 | 32.43 | 717.35 | 60 |
| 79 | 1.2.5.1.2 | SOLADO E=4" F'C= 100 KG/CM2 | 3d | 2022-04-08 | 2022-04-11 | 78 | 70d | 0d | start no earlier than 2021-03-01 | CEMENTO PORTLAND TIPO V [4601%]; OPERARIO [79.9%]; OFICIAL [79.9%]; PEON [239.6%]; MEZCLADORA DE CONCRETO 11 P3 (23 HP) [79.9%]; HORMIGON [2012.9%]; AGUA [172.5%] | 115.01h | 4,581.2 | 01.05.01.02 | 000000000000071 | 143.78 | 33.9 | 4874.14 | 60 |
| 80 | 1.2.5.2 | **BUZONES DE INSPECION TIPO I** | 42d | 2022-04-11 | 2022-05-23 |  | 70d |  |  |  | 4134.82h | 159,618.66 | 01.05.02 | 000000000000016 |  |  |  |  |
| 81 | 1.2.5.2.1 | BUZÓN Øint=1.20M HASTA H=1.50 (f`c=245Kg/cm2) | 30d | 2022-04-11 | 2022-05-11 | 79 | 70d | 0d | start no earlier than 2021-03-01 | CEMENTO PORTLAND TIPO V [94887%]; CURADOR MENBRANIL [1131%]; OPERARIO [195%]; OFICIAL [195%]; PEON [585%]; VIBRADOR DE CONCRETO 4 HP 1.25" [97.5%]; MEZCLADORA DE CONCRETO 11 P3 (23 HP) [97.5%]; CIZALLA ELECTRICA DE FIERRO [24.4%]; ALAMBRE NEGRO #8 [1170%]; ALAMBRE NEGRO N° 16 [2340%]; ACERO CORRUGADO fy = 4200 kg/cm2 GRADO 60 [207207%]; IMPERMEABILIZANTE EN POLVO [7090.2%]; ENCOFRADO Y DESENCOFRADO METALICO [51.2%]; PIEDRA CHANCADA 1/2" [3944.5%]; ARENA FINA [509.7%]; ARENA GRUESA [3867.2%]; MADERA TORNILLO [11622%]; MARCO FºFº Y PARA TAPA DE CONCRETO D=0.60M [3900%]; TAPA DE CONCRETO ARMADO P/BUZON [3900%] | 2989.35h | 88,653.69 | 01.05.02.01 | 000000000000072 | 39 | 2379.68 | 92807.52 |  |
| 82 | 1.2.5.2.2 | BUZÓN Øint=1.20M H=1.51 HASTA H=2.00 (f`c=245Kg/cm2) | 6d | 2022-05-11 | 2022-05-17 | 81 | 70d | 0d | start no earlier than 2021-03-01 | CEMENTO PORTLAND TIPO V [22768%]; CURADOR MENBRANIL [256%]; OPERARIO [177.8%]; OFICIAL [177.8%]; PEON [533.3%]; VIBRADOR DE CONCRETO 4 HP 1.25" [88.9%]; MEZCLADORA DE CONCRETO 11 P3 (23 HP) [88.9%]; CIZALLA ELECTRICA DE FIERRO [22.2%]; ALAMBRE NEGRO #8 [240%]; ALAMBRE NEGRO N° 16 [480%]; ACERO CORRUGADO fy = 4200 kg/cm2 GRADO 60 [42504%]; IMPERMEABILIZANTE EN POLVO [1907.2%]; ENCOFRADO Y DESENCOFRADO METALICO [35%]; PIEDRA CHANCADA 1/2" [809.1%]; ARENA FINA [137.1%]; ARENA GRUESA [793.3%]; MADERA TORNILLO [2384%]; MARCO FºFº Y PARA TAPA DE CONCRETO D=0.60M [800%]; TAPA DE CONCRETO ARMADO P/BUZON [800%] | 539.47h | 29,841.36 | 01.05.02.02 | 000000000000073 |  | 2819.95 | 22559.6 | 1.5 |
| 83 | 1.2.5.2.3 | BUZÓN Øint=1.20M H=2.01 HASTA H=2.50 (f`c=245Kg/cm2) | 6d | 2022-05-17 | 2022-05-23 | 82 | 70d | 0d | start no earlier than 2021-03-01 | CEMENTO PORTLAND TIPO V [19560%]; CURADOR MENBRANIL [600%]; OPERARIO [200%]; OFICIAL [200%]; PEON [600%]; VIBRADOR DE CONCRETO 4 HP 1.25"; MEZCLADORA DE CONCRETO 11 P3 (23 HP); CIZALLA ELECTRICA DE FIERRO [25%]; ALAMBRE NEGRO #8 [600%]; ALAMBRE NEGRO N° 16 [600%]; ACERO CORRUGADO fy = 4200 kg/cm2 GRADO 60 [31878%]; IMPERMEABILIZANTE EN POLVO [1770.6%]; ENCOFRADO Y DESENCOFRADO METALICO [37.5%]; PIEDRA CHANCADA 1/2" [801.5%]; ARENA FINA [127.3%]; ARENA GRUESA [785.8%]; MADERA TORNILLO [2400%]; MARCO FºFº Y PARA TAPA DE CONCRETO D=0.60M [600%]; TAPA DE CONCRETO ARMADO P/BUZON [600%] | 606h | 41,123.61 | 01.05.02.03 | 000000000000096 |  | 3654.99 | 21929.94 |  |
| 84 | 1.2.5.3 | **BUZONES DE INSPECION TIPO II** | 24d | 2022-05-23 | 2022-06-16 |  | 70d |  |  |  | 1972.43h | 93,433.92 | 01.05.03 | 000000000000018 |  |  |  |  |
| 85 | 1.2.5.3.1 | BUZÓN Øint=1.20M H=2.51 HASTA H=3.00 (f`c=245Kg/cm2) | 4d | 2022-05-23 | 2022-05-27 | 83 | 70d | 0d | start no earlier than 2021-03-01 | CEMENTO PORTLAND TIPO V [11262%]; CURADOR MENBRANIL [300%]; OPERARIO [200%]; OFICIAL [200%]; PEON [600%]; VIBRADOR DE CONCRETO 4 HP 1.25"; MEZCLADORA DE CONCRETO 11 P3 (23 HP); CIZALLA ELECTRICA DE FIERRO [25%]; ALAMBRE NEGRO #8 [300%]; ALAMBRE NEGRO N° 16 [300%]; ACERO CORRUGADO fy = 4200 kg/cm2 GRADO 60 [56314.8%]; IMPERMEABILIZANTE EN POLVO [1344.9%]; ENCOFRADO Y DESENCOFRADO METALICO [28.1%]; PIEDRA CHANCADA 1/2" [449.4%]; ARENA FINA [96.7%]; ARENA GRUESA [440.6%]; MADERA TORNILLO [1200%]; MARCO FºFº Y PARA TAPA DE CONCRETO D=0.60M [300%]; TAPA DE CONCRETO ARMADO P/BUZON [300%] | 401h | 11,674.14 | 01.05.03.01 | 000000000000097 |  | 4918.22 | 14754.66 | 0.75 |
| 86 | 1.2.5.3.2 | BUZÓN Øint=1.20M H=3.01 HASTA H=3.50 (f`c=245Kg/cm2) | 2d | 2022-05-27 | 2022-05-29 | 85 | 70d | 0d | start no earlier than 2021-03-01 | CEMENTO PORTLAND TIPO V [6644%]; CURADOR MENBRANIL; OPERARIO [117.6%]; OFICIAL [117.6%]; PEON [352.9%]; VIBRADOR DE CONCRETO 4 HP 1.25" [58.8%]; MEZCLADORA DE CONCRETO 11 P3 (23 HP) [58.8%]; CIZALLA ELECTRICA DE FIERRO [14.7%]; ALAMBRE NEGRO #8; ALAMBRE NEGRO N° 16; ACERO CORRUGADO fy = 4200 kg/cm2 GRADO 60 [20934.6%]; IMPERMEABILIZANTE EN POLVO [519.7%]; ENCOFRADO Y DESENCOFRADO METALICO [18.8%]; PIEDRA CHANCADA 1/2" [275.3%]; ARENA FINA [37.4%]; ARENA GRUESA [269.9%]; MADERA TORNILLO [400%]; MARCO FºFº Y PARA TAPA DE CONCRETO D=0.60M; TAPA DE CONCRETO ARMADO P/BUZON | 118.29h | 33,414.4 | 01.05.03.02 | 000000000000074 |  | 5688.11 | 5688.11 | 0.85 |
| 87 | 1.2.5.3.3 | BUZÓN Øint=1.20M H=3.51 HASTA H=4.00 (f`c=245Kg/cm2) | 12d | 2022-05-29 | 2022-06-10 | 86 | 70d | 0d | start no earlier than 2021-03-01 | CEMENTO PORTLAND TIPO V [58544%]; CURADOR MENBRANIL [800%]; OPERARIO [190.5%]; OFICIAL [190.5%]; PEON [571.4%]; VIBRADOR DE CONCRETO 4 HP 1.25" [95.2%]; MEZCLADORA DE CONCRETO 11 P3 (23 HP) [95.2%]; CIZALLA ELECTRICA DE FIERRO [23.8%]; ALAMBRE NEGRO #8 [800%]; ALAMBRE NEGRO N° 16 [800%]; ACERO CORRUGADO fy = 4200 kg/cm2 GRADO 60 [184781%]; IMPERMEABILIZANTE EN POLVO [4728%]; ENCOFRADO Y DESENCOFRADO METALICO [26.7%]; PIEDRA CHANCADA 1/2" [2420.3%]; ARENA FINA [339.8%]; ARENA GRUESA [2372.9%]; MADERA TORNILLO [3200%]; MARCO FºFº Y PARA TAPA DE CONCRETO D=0.60M [800%]; TAPA DE CONCRETO ARMADO P/BUZON [800%] | 1145.6h | 22,457.01 | 01.05.03.03 | 000000000000075 |  | 6479.95 | 51839.6 | 0.7 |
| 88 | 1.2.5.3.4 | BUZÓN Øint=1.20M H=4.01 HASTA H=4.50 (f`c=245Kg/cm2) | 2d | 2022-06-10 | 2022-06-12 | 87 | 70d | 0d | start no earlier than 2021-03-01 | CEMENTO PORTLAND TIPO V [7992%]; CURADOR MENBRANIL; OPERARIO [153.8%]; OFICIAL [153.8%]; PEON [461.5%]; VIBRADOR DE CONCRETO 4 HP 1.25" [76.9%]; MEZCLADORA DE CONCRETO 11 P3 (23 HP) [76.9%]; CIZALLA ELECTRICA DE FIERRO [19.2%]; ALAMBRE NEGRO #8; ALAMBRE NEGRO N° 16; ACERO CORRUGADO fy = 4200 kg/cm2 GRADO 60 [25260.5%]; IMPERMEABILIZANTE EN POLVO [662.3%]; ENCOFRADO Y DESENCOFRADO METALICO [18.8%]; PIEDRA CHANCADA 1/2" [329.8%]; ARENA FINA [47.6%]; ARENA GRUESA [323.3%]; MADERA TORNILLO [400%]; MARCO FºFº Y PARA TAPA DE CONCRETO D=0.60M; TAPA DE CONCRETO ARMADO P/BUZON | 153.77h | 8,014.81 | 01.05.03.04 | 000000000000108 |  | 6994.82 | 6994.82 | 0.65 |
| 89 | 1.2.5.3.5 | BUZÓN Øint=1.20M H=4.51 HASTA H=5.00 (f`c=245Kg/cm2) | 2d | 2022-06-12 | 2022-06-14 | 88 | 70d | 0d | start no earlier than 2021-03-01 | CEMENTO PORTLAND TIPO V [8666%]; CURADOR MENBRANIL; OPERARIO [153.8%]; OFICIAL [153.8%]; PEON [461.5%]; VIBRADOR DE CONCRETO 4 HP 1.25" [76.9%]; MEZCLADORA DE CONCRETO 11 P3 (23 HP) [76.9%]; CIZALLA ELECTRICA DE FIERRO [19.2%]; ALAMBRE NEGRO #8; ALAMBRE NEGRO N° 16; ACERO CORRUGADO fy = 4200 kg/cm2 GRADO 60 [27423.5%]; IMPERMEABILIZANTE EN POLVO [733.7%]; ENCOFRADO Y DESENCOFRADO METALICO [18.8%]; PIEDRA CHANCADA 1/2" [357%]; ARENA FINA [52.7%]; ARENA GRUESA [350%]; MADERA TORNILLO [400%]; MARCO FºFº Y PARA TAPA DE CONCRETO D=0.60M; TAPA DE CONCRETO ARMADO P/BUZON | 153.77h | 8,338.63 | 01.05.03.05 | 000000000000098 |  | 7301.79 | 7301.79 | 0.65 |
| 90 | 1.2.5.3.6 | BUZÓN Øint=1.20M H=5.01 HASTA H=5.50 (f`c=245Kg/cm2) | 2d | 2022-06-15 | 2022-06-16 | 89 | 70d | 0d |  |  |  | 9,534.93 | 01.05.03.06 |  |  |  |  |  |

| ID | WBS | Task | Duration | Start | Finish | Predecessors | Total slack | Free slack | Constraint | Resources | Work | Cost | Text1 | Text8 | Text3 | Text4 | Text6 | Text2 |
| --- | --- | --- | --- | --- | --- | --- | --- | --- | --- | --- | --- | --- | --- | --- | --- | --- | --- | --- |
| 91 | 1.2.5.4 | **CAIDAS ESPECIALES** | 3d | 2022-06-16 | 2022-06-19 |  | 70d |  |  |  | 53.89h | 4,394.16 | 01.05.04 | 000000000000017 |  |  |  |  |
| 92 | 1.2.5.4.1 | CAIDA ESPECIAL A CAMARA DE INSPECCION H=1.50M A 2.00M | 3d | 2022-06-16 | 2022-06-19 | 90 | 70d | 0d | start no earlier than 2021-03-01 | CEMENTO PORTLAND TIPO MS. [41.8%]; OPERARIO [74.3%]; OFICIAL [0.4%]; PEON [149.7%]; MEZCLADORA DE CONCRETO 11 P3 (23 HP) [0.2%]; TUBERIA PVC UF NTP ISO 21138:2010 / 4435:2005 SN4 D=200 mm [600%]; PIEDRA GRANDE [7.2%]; HORMIGON [11.9%]; MADERA TORNILLO [492%]; ABRAZADERA DE ALUMINIO FIJADAS AL CUERPO DEL BUZON CON TIRAFONES [800%]; TEE 200x200MM PVC ISO 16422:2012 [400%]; CODO 200MM/90º PVC ISO 4435 [400%]; ANILLO DE JEBE P/TUB. PVC - UF DN 200MM [1200%] | 53.89h | 4,394.16 | 01.05.04.01 | 000000000000078 | 1037.63 | 4150.52 | 1.8 |  |
| 93 | 1.2.5.5 | **DADOS DE ANCLAJE DE TUBERÍA** | 14d | 2022-06-19 | 2022-07-03 |  | 70d |  |  |  | 1158.66h | 36,660.96 | 01.05.05 | 000000000000019 |  |  |  |  |
| 94 | 1.2.5.5.1 | DADOS DE CONCRETO F´C=175 KG/CM2, 0.50 x 0.50 x 0.50 | 14d | 2022-06-19 | 2022-07-03 | 92 | 70d |  | start no earlier than 2021-03-01 | CEMENTO PORTLAND TIPO V [16787.5%]; YESO EN BOLSAS DE 18 kg [63200%]; OPERARIO [188.1%]; OFICIAL [188.1%]; PEON [564.3%]; MEZCLADORA DE CONCRETO 11 P3 (23 HP) [94.1%]; PIEDRA CHANCADA 1/2" [1106%]; ARENA GRUESA [1106%]; AGUA [316%]; MADERA TORNILLO [19434%] | 1158.66h | 36,660.96 | 01.05.05.01 | 000000000000076 | 252.04 | 39822.32 | 12 | 158 |
| 95 | 1.2.6 | **CONEXIONES DOMICILIARIAS** | 171d | 2022-03-25 | 2022-09-11 |  | 0d |  |  |  | 6587.34h | 730,604.67 | 01.06 | 000000000000020 |  |  |  |  |
| 96 | 1.2.6.1 | EXCAV. PARA CONEXIONES DOMICILIARIAS P/ALCANTARILLADO | 39d | 2022-03-25 | 2022-05-02 | 16 | 0d |  | start no earlier than 2021-03-01 | PEON [200%]; RETROEXCAVADORA SOBRE ORUGAS 115 - 165 HP [25%] | 702h | 68,016.24 | 01.06.01 | 000000000000081 | 17.21 | 63332.8 | 32 | 3680 |
| 97 | 1.2.6.2 | REFINE Y NIVELACION EN TERRENO NORMAL | 20d | 2022-05-03 | 2022-05-22 | 96 | 0d |  | start no earlier than 2021-03-01 | PEON [191.1%]; EXCAVADORA S/ORUGA 195-225 HP 3.0 Y3. [95.8%] | 459h | 25,244.8 | 01.06.02 | 000000000000082 | 6.87 | 25281.6 | 350 | 3680 |
| 98 | 1.2.6.3 | CAMA DE APOYO CON MATERIAL DE PRESTAMO E=15cm PARA CONEXIONES DOMICILIARIAS | 20d | 2022-05-22 | 2022-06-11 | 97 | 0d |  | start no earlier than 2021-03-01 | OFICIAL; PEON [200%]; RETROEXCAVADORA SOBRE ORUGAS 115 - 165 HP; AFIRMADO [55200%] | 640h | 70,398.4 | 01.06.03 | 000000000000083 | 16.22 | 59689.6 | 160 | 3680 |
| 99 | 1.2.6.4 | RELLENO COMPACT. C/MAT. PROPIO T. NORMAL | 48d | 2022-07-25 | 2022-09-11 | 100 | 0d |  | start no earlier than 2021-03-01 | OPERARIO [98.9%]; PEON [296.8%]; COMPACTADORA VIBRATORIA TIPO PLANCHA 7 HP [98.9%]; MINICARGADOR FRONTAL 64 HP [98.9%]; CAMION CISTERNA 4X2(AGUA) 122HP 2000 gal [49.5%]; AGUA [588800%] | 2468.97h | 199,707.23 | 01.06.04 | 000000000000084 | 50.07 | 184257.6 | 60 | 3680 |
| 100 | 1.2.6.5 | CONEXIÓN DOMICILIARIA DESAGUE TUBO PVC DN 200-160 MM L=8.00M | 44d | 2022-06-11 | 2022-07-25 | 98 | 0d |  | start no earlier than 2021-03-01 | CEMENTO PORTLAND TIPO V [46000%]; LUBRICANTE PARA TUBERIALUBRICANTE PARA TUBERIA [2760%]; OPERARIO [199.1%]; OFICIAL [199.1%]; PEON [260.1%]; ALAMBRE NEGRO N° 16 [27600%]; TUBERIA PVC UF NTP ISO 21138:2010 / 4435:2005 SN4 D=160 mm [370300%]; PIEDRA CHANCADA 1/2" [51520%]; ARENA FINA [2300%]; ARENA GRUESA [4600%]; CACHIMBA DE 160 MM X 200MM [46000%]; PEGAMENTO PARA PVC [6900%]; REJILLA METALICA PARA RETENCION DE SOLIDOS [46000%]; CAJA DE CONCRETO PREFABRICADA DE DESAGUE [46000%]; ANILLO DE JEBE P/TUB. PVC - UF DN 160MM [46000%] | 2317.37h | 367,238 | 01.06.05 | 000000000000085 | 615.72 | 283231.2 |  | 460 |
| 101 | 1.2.7 | **OTROS** | 26d | 2022-07-25 | 2022-08-20 |  | 22d |  |  |  | 2791.98h | 117,671.57 | 01.07 | 000000000000021 |  |  |  |  |
| 102 | 1.2.7.1 | LIMPIEZA DE TERRENO | 7d | 2022-08-14 | 2022-08-20 | 104 | 22d |  | start no earlier than 2021-03-01 | PEON [98.1%] | 54.94h | 5,809.52 | 01.07.01 | 000000000000080 | 1.4 | 6043.23 | 100 | 4316.59 |
| 103 | 1.2.7.2 | **REPOSICION DE VEREDAS** | 19d | 2022-07-25 | 2022-08-13 |  | 22d |  |  |  | 1989.09h | 60,768.58 | 01.07.02 | 000000000000109 |  |  |  |  |
| 104 | 1.2.7.2.1 | ENCOFRADO Y DESENCOFRADO PARA VEREDAS | 19d | 2022-07-25 | 2022-08-13 | 105SS | 22d | 0d | start no earlier than 2021-03-01 | OPERARIO [96.8%]; OFICIAL [96.8%]; ALAMBRE NEGRO #8 [4636.8%]; CLAVOS C/C DE 3" [5299.2%]; MADERA TORNILLO [66240%] | 294.41h | 12,004.9 | 01.07.02.01 | 000000000000112 | 50.33 | 11112.86 | 12 | 220.8 |
| 105 | 1.2.7.2.2 | BASE AFIRMADA PARA VEREDAS E=0.10M | 15d | 2022-07-25 | 2022-08-09 | 99SS | 22d | 0d | start no earlier than 2021-03-01 | OFICIAL [96.6%]; PEON [483%]; COMPACTADORA VIBRATORIA TIPO PLANCHA 7 HP [96.6%]; AFIRMADO [9273.6%] | 811.44h | 7,998.48 | 01.07.02.02 | 000000000000113 | 10.41 | 8044.85 | 200 | 772.8 |
| 106 | 1.2.7.2.3 | REPOSICION DE VEREDA, CONCRETO F´C=175KG/CM2 E=0.10M | 12d | 2022-07-25 | 2022-08-06 | 104SS | 36d |  | start no earlier than 2021-03-01 | CEMENTO PORTLAND TIPO MS. [65147%]; OPERARIO [184%]; OFICIAL [92%]; PEON [552%]; MEZCLADORA DE CONCRETO 11 P3 (23 HP) [92%]; PIEDRA CHANCADA 1/2" [4173.1%]; ARENA GRUESA [4250.4%] | 883.23h | 40,765.2 | 01.07.02.03 | 000000000000114 | 51.6 | 39876.48 | 70 | 772.8 |
| 107 | 1.2.7.3 | **REPOSICION DE PAVIMENTO DE ADOQUIN** | 13d | 2022-07-27 | 2022-08-09 |  | 33d |  |  |  | 543.4h | 39,444.13 | 01.07.03 | 000000000000110 |  |  |  |  |
| 108 | 1.2.7.3.1 | CONFORMACION DE CAPA DE SUB BASE GRANULAR AFIRMADO E=0.20M C/EQUIPO | 5d | 2022-07-27 | 2022-08-01 | 55SS | 33d | 0d | start no earlier than 2021-03-01 | OPERARIO [8.5%]; OFICIAL [84.6%]; COMPACTADORA VIBRATORIA TIPO PLANCHA 7 HP [84.6%]; AFIRMADO [8461.5%] | 71.08h | 5,158.13 | 01.07.03.01 | 000000000000115 | 15.28 | 5171.67 | 80 | 338.46 |
| 109 | 1.2.7.3.2 | CONFORMACION DE CAPA DE BASE GRANULAR AFIRMADO E=0.20M C/EQUIPO | 5d | 2022-07-27 | 2022-08-01 | 108SS | 33d | 0d | start no earlier than 2021-03-01 | OPERARIO [9.6%]; OFICIAL [96.7%]; COMPACTADORA VIBRATORIA TIPO PLANCHA 7 HP [96.7%]; AFIRMADO [8461.5%] | 81.23h | 5,354.44 | 01.07.03.02 | 000000000000116 | 15.85 | 5364.59 | 70 | 338.46 |
| 110 | 1.2.7.3.3 | BASE DE ARENA E=0.05m | 2d | 2022-08-01 | 2022-08-03 | 109 | 33d | 0d | start no earlier than 2021-03-01 | OPERARIO [282%]; PEON [188.1%]; ARENA GRUESA [2115.4%] | 75.21h | 2,667.06 | 01.07.03.03 | 000000000000117 | 7.95 | 2690.76 | 180 | 338.46 |
| 111 | 1.2.7.3.4 | REPOSICION DE ADOQUINES DE CONCRETO | 6d | 2022-08-03 | 2022-08-09 | 110 | 33d |  | start no earlier than 2021-03-01 | OPERARIO [188.1%]; OFICIAL [94%]; PEON [282.1%]; COMPACTADORA VIBRATORIA TIPO PLANCHA 7 HP [94%]; ADOQUIN DE CONCRETO DE 0.10X0.20X0.08 m. [35538.3%]; ARENA FINA [1015.4%] | 315.88h | 26,264.5 | 01.07.03.04 | 000000000000120 | 77.85 | 26349.11 | 60 | 338.46 |
| 112 | 1.2.7.4 | **REPOSICION DE LOSA DE CONCRETO** | 7d | 2022-08-01 | 2022-08-08 |  | 34d |  |  |  | 204.55h | 11,649.34 | 01.07.04 | 000000000000111 |  |  |  |  |
| 113 | 1.2.7.4.1 | CONFORMACION DE CAPA DE SUB BASE GRANULAR AFIRMADO E=0.20M C/EQUIPO | 2d | 2022-08-01 | 2022-08-03 | 108 | 34d | 0d | start no earlier than 2021-03-01 | OPERARIO [5.6%]; OFICIAL [56%]; COMPACTADORA VIBRATORIA TIPO PLANCHA 7 HP [56%]; AFIRMADO [2241.5%] | 18.83h | 1,366.42 | 01.07.04.01 | 000000000000121 | 15.28 | 1370 | 80 | 89.66 |
| 114 | 1.2.7.4.2 | CONFORMACION DE CAPA DE BASE GRANULAR AFIRMADO E=0.20M C/EQUIPO | 2d | 2022-08-03 | 2022-08-05 | 113 | 34d | 0d | start no earlier than 2021-03-01 | OPERARIO [6.4%]; OFICIAL [64.1%]; COMPACTADORA VIBRATORIA TIPO PLANCHA 7 HP [64.1%]; AFIRMADO [2241.5%] | 21.52h | 1,418.42 | 01.07.04.02 | 000000000000122 | 15.85 | 1421.11 | 70 | 89.66 |
| 115 | 1.2.7.4.3 | ENCOFRADO Y DESENCOFRADO DE LOSAS | 1d | 2022-08-05 | 2022-08-06 | 114 | 34d | 0d | start no earlier than 2021-03-01 | OPERARIO [5.1%]; OFICIAL [5.1%]; PEON [10.2%]; ALAMBRE NEGRO #8 [375.9%]; CLAVOS C/C DE 3" [25.6%]; MADERA TORNILLO [409.6%] | 1.64h | 78.08 | 01.07.04.03 | 000000000000123 | 56.6 | 72.45 | 25 | 1.28 |
| 116 | 1.2.7.4.4 | REPOSICION DE LOSA DE CONCRETO F'C=210KG/CM2 | 2d | 2022-08-06 | 2022-08-08 | 115 | 34d |  | start no earlier than 2021-03-01 | CEMENTO PORTLAND TIPO MS. [17445.9%]; OPERARIO [119.5%]; OFICIAL [119.5%]; PEON [597.7%]; VIBRADOR DE CONCRETO 4 HP 1.25" [119.5%]; MEZCLADORA DE CONCRETO 11 P3 (23 HP) [59.8%]; PIEDRA CHANCADA 1/2" [950.3%]; ARENA GRUESA [932.4%] | 162.57h | 8,786.42 | 01.07.04.04 | 000000000000125 | 475.52 | 8526.07 | 15 | 17.93 |

| ID | WBS | Task | Duration | Start | Finish | Predecessors | Total slack | Free slack | Constraint | Resources | Work | Cost | Text1 | Text8 | Text2 | Text3 | Text4 | Text6 |
| --- | --- | --- | --- | --- | --- | --- | --- | --- | --- | --- | --- | --- | --- | --- | --- | --- | --- | --- |
| 117 | 1.3 | **SISTEMA DE AGUA POTABLE** | 115d | 2022-03-16 | 2022-07-08 |  | 65d |  |  |  | 370478h | 1,371,497.35 | 02 | 000000000000001 |  |  |  |  |
| 118 | 1.3.1 | **TRABAJOS PRELIMINARES** | 31d | 2022-03-16 | 2022-04-15 |  | 65d |  |  |  | 1418.53h | 61,605.88 | 02.01 | 000000000000002 |  |  |  |  |
| 119 | 1.3.1.1 | TRAZO Y REPLANTEO DE OBRA | 9d | 2022-03-16 | 2022-03-24 | 6SS | 65d | 0d | start no earlier than 2021-03-01 | YESO EN BOLSAS DE 18 kg [21891%]; MIRAS [12.2%]; JALONES [12.2%]; PINTURA ESMALTE [4378.2%]; PEON [194.6%]; OPERARIO TOPOGRAFO [97.3%]; NIVEL TOPOGRAFICO [97.3%]; TEODOLITO [97.3%]; ESTACA DE FIERRO CORRUGADO [17512.8%]; CORDEL [43781.9%] | 367.77h | 13,176.68 | 02.01.01 | 000000000000013 | 4378.19 | 2.66 | 11645.99 | 500 |
| 120 | 1.3.1.2 | EXTRACCION Y ELIMINACION DE TUBERIA EXISTENTE | 22d | 2022-03-25 | 2022-04-15 | 119 | 65d | 0d | start no earlier than 2021-03-01 | PEON [497.5%]; RETROEXCAVADORA SOBRE ORUGAS 115 - 165 HP | 1050.77h | 48,429.2 | 02.01.02 | 000000000000055 | 4378.19 | 8.9 | 38965.89 | 200 |
| 121 | 1.3.2 | **MOVIMIENTO DE TIERRAS** | 69d | 2022-04-16 | 2022-06-23 |  | 65d |  |  |  | 6915.3h | 292,948.74 | 02.02 | 000000000000003 |  |  |  |  |
| 122 | 1.3.2.1 | EXCAVACION CON EQUIPO EN TERRENO NORMAL, Hprom=1.50m | 30d | 2022-04-16 | 2022-05-15 | 120 | 65d | 0d | start no earlier than 2021-03-01 | PEON [98.7%]; RETROEXCAVADORA SOBRE ORUGAS 115 - 165 HP [98.7%] | 473.55h | 58,115.04 | 02.02.01 | 000000000000016 | 4378.19 | 10.16 | 44482.41 | 120 |
| 123 | 1.3.2.2 | REFINE Y NIVELACION EN TERRENO NORMAL HASTA H=1.50 M | 40d | 2022-04-16 | 2022-05-25 | 122SS | 80d | 0d | start no earlier than 2021-03-01 | PEON [198.6%] | 635.46h | 15,094.18 | 02.02.02 | 000000000000017 | 4378.19 | 3.11 | 13616.17 | 90 |
| 124 | 1.3.2.3 | CAMA DE APOYO CON MATERIAL DE PRESTAMO P/TUBERIA E=0.15M | 40d | 2022-04-16 | 2022-05-25 | 123SS | 80d | 0d | start no earlier than 2021-03-01 | OFICIAL; PEON [199%]; AFIRMADO [82091.1%] | 955.24h | 62,540.04 | 02.02.03 | 000000000000018 | 4378.19 | 12.8 | 56040.83 | 100 |
| 125 | 1.3.2.4 | RELLENO PROTECTOR C/MAT. PROPIO ZARANDEADO HASTA H=0.30M, S/CLAVE DE TUBERIA, A= 0.60M | 40d | 2022-05-14 | 2022-06-23 | 136 | 80d | 0d | start no earlier than 2021-03-01 | OFICIAL; PEON [398%]; COMPACTADORA VIBRATORIA TIPO PLANCHA 7 HP; ZARANDA [199%]; AGUA [109455%] | 2547.31h | 74,536.72 | 02.02.04 | 000000000000019 | 4378.19 | 15.29 | 66942.53 | 80 |
| 126 | 1.3.2.5 | RELLENO Y COMPACTACION DE ZANJA CON MATERIAL PROPIO SELECCIONADO C/MAQ. HASTA 0.90 DE PROF./PROM. | 40d | 2022-05-14 | 2022-06-23 | 125SS | 80d | 0d | start no earlier than 2021-03-01 | OPERARIO [99.3%]; PEON [397.1%]; COMPACTADORA VIBRATORIA TIPO PLANCHA 7 HP [99.3%]; ZARANDA [99.3%]; AGUA [31304.1%] | 2223.84h | 71,881.72 | 02.02.05 | 000000000000020 | 4378.19 | 14.79 | 64753.43 | 70 |
| 127 | 1.3.2.6 | ELIMINACION DE MATERIAL DE EXEDENTE Dp=5KM | 2d | 2022-05-16 | 2022-05-17 | 122 | 117d |  | start no earlier than 2021-03-01 | CARGADOR SOBRE LLANTAS DE 125-135 HP 2.5 yd3 [10.4%]; PEON [162.8%]; CAMION VOLQUETE 6 X 4 330 HP 10 M3 [326.1%] | 79.89h | 10,781.04 | 02.02.06 | 000000000000021 | 879.85 | 10.91 | 9599.16 | 540 |
| 128 | 1.3.3 | **SUMINISTRO DE TUBERIAS DE PVC ISO 16422:2012 4435:2005** | 2d | 2022-04-16 | 2022-04-17 |  | 80d |  |  |  |  | 200,352.5 | 02.03 | 000000000000004 |  |  |  |  |
| 129 | 1.3.3.1 | SUMINISTRO DE TUBERIA PVC, UF, PN8, D=110 mm, NTP ISO 16422:2012. | 1d | 2022-04-16 | 2022-04-16 | 124SS | 80d | 0d | start no earlier than 2021-03-01 | LUBRICANTE PARA TUBERIALUBRICANTE PARA TUBERIA [23130.4%]; TUBERIA PVC-O UF PN8 D=110 mm NTP ISO 16422:2012. [404782%] |  | 150,828.66 | 02.03.01 | 000000000000024 | 3855.07 | 18.54 | 71473 |  |
| 130 | 1.3.3.2 | SUMINISTRO DE TUBERIA PVC, UF, PN8, D=160 mm, NTP ISO 16422:2012. | 1d | 2022-04-16 | 2022-04-17 | 129 | 80d | 0d | start no earlier than 2021-03-01 | LUBRICANTE PARA TUBERIALUBRICANTE PARA TUBERIA [1046.2%]; TUBERIA PVC-O UF PN8 D=160 mm NTP ISO 16422:2012. [54927.6%] |  | 49,523.84 | 02.03.02 | 000000000000023 | 523.12 | 35.37 | 18502.75 |  |
| 131 | 1.3.4 | **INSTALACION DE TUBERIAS DE PVC ISO 16422:2012** | 17d | 2022-04-18 | 2022-05-04 |  | 80d |  |  |  | 699.96h | 16,147.79 | 02.04 | 000000000000005 |  |  |  |  |
| 132 | 1.3.4.1 | INSTALACIÓN DE TUB. PVC, UF, DN 110mm, NTP ISO 16422:2012 | 14d | 2022-04-18 | 2022-05-01 | 130 | 80d | 0d | start no earlier than 2021-03-01 | OPERARIO [196.5%]; OFICIAL [98.4%]; PEON [196.5%]; ESCOFINA PLANA [34.4%] | 589.05h | 13,566.37 | 02.04.01 | 000000000000025 | 3855.07 | 3.19 | 12297.67 | 280 |
| 133 | 1.3.4.2 | INSTALACIÓN DE TUB. PVC, UF, DN 160mm, NTP ISO 16422:2012 | 3d | 2022-05-02 | 2022-05-04 | 132 | 80d | 0d | start no earlier than 2021-03-01 | OPERARIO [139.5%]; OFICIAL [139.5%]; PEON [139.5%]; ESCOFINA PLANA [43.6%] | 110.9h | 2,581.42 | 02.04.02 | 000000000000026 | 523.12 | 4.39 | 2296.5 | 250 |
| 134 | 1.3.5 | **PRUEBAS HIDRAULICAS Y DESINFECCION DE TUBERIAS** | 10d | 2022-05-04 | 2022-05-14 |  | 80d |  |  |  | 331.45h | 35,306.81 | 02.05 | 000000000000006 |  |  |  |  |
| 135 | 1.3.5.1 | DOBLE PRUEBA HIDRÁULICA + DESINFECCION TUB. DN 110 MM ZANJA TAPADA | 8d | 2022-05-04 | 2022-05-12 | 133 | 80d | 0d | start no earlier than 2021-03-01 | OPERARIO [96.4%]; OFICIAL [96.4%]; PEON [96.4%]; BALDE PRUEBA TAPON ABRAZADERA Y ACCESORIOS [10023.2%]; MOTOFUMIGADORA 5.5 HP Q=30 L/min. [96.4%]; CAMION CISTERNA 4X2(AGUA) 122HP 2000 gal [48.2%]; HIPOCLORITO DE CALCIO AL 70% [19275.3%]; ABRAZADERA DE PVC 110MM [385.5%]; CORPORATION RT NIPLE TUERCA EMPAQUE 1/2" [3855.1%]; CINTA TEFLON [3855.1%] | 277.56h | 29,422.61 | 02.05.01 | 000000000000027 | 3855.07 | 6.66 | 25674.77 | 500 |
| 136 | 1.3.5.2 | DOBLE PRUEBA HIDRÁULICA + DESINFECCION TUB. DN 160 MM ZANJA TAPADA | 2d | 2022-05-12 | 2022-05-14 | 135 | 80d | 0d | start no earlier than 2021-03-01 | OPERARIO [74.9%]; OFICIAL [74.9%]; PEON [74.9%]; BALDE PRUEBA TAPON ABRAZADERA Y ACCESORIOS [523.1%]; MOTOFUMIGADORA 5.5 HP Q=30 L/min. [74.9%]; CAMION CISTERNA 4X2(AGUA) 122HP 2000 gal [37.3%]; HIPOCLORITO DE CALCIO AL 70% [3661.8%]; ABRAZADERA DE PVC 160MM [523.1%]; CORPORATION RT NIPLE TUERCA EMPAQUE 1/2" [523.1%]; CINTA TEFLON [523.1%] | 53.88h | 5,884.2 | 02.05.02 | 000000000000028 | 523.12 | 9.04 | 4729 | 350 |
| 137 | 1.3.6 | **SUMINISTRO E INSTALACION DE VALVULAS Y ACCESORIOS** | 18d | 2022-04-18 | 2022-05-05 |  | 129d |  |  |  | 684.35h | 53,935.87 | 02.06 | 000000000000007 |  |  |  |  |
| 138 | 1.3.6.1 | SUMINISTRO E INST. DE TEE PVC C-10 160x110 MM | 1d | 2022-04-18 | 2022-04-18 | 132SS | 129d | 0d | start no earlier than 2021-03-01 | CEMENTO PORTLAND TIPO MS. [294.4%]; LUBRICANTE PARA TUBERIALUBRICANTE PARA TUBERIA [10%]; OPERARIO [130.6%]; OFICIAL [5.6%]; PEON [84.9%]; VIBRADOR DE CONCRETO 4 HP 1.25" [5.6%]; MEZCLADORA DE CONCRETO 11 P3 (23 HP) [2.8%]; PIEDRA CHANCADA 1/2" [26.9%]; ARENA GRUESA [21.4%]; AGUA [7.6%]; ANILLO DE JEBE P/TUB. PVC - UF DN 160MM [1500%]; ANILLO DE JEBE P/TUB. PVC - UF DN 110MM [1500%]; TEE DE 160 X 110 MM PVC C-10 [500%] | 18.36h | 1,450.95 | 02.06.01 | 000000000000029 |  | 280.38 | 1401.9 |  |
| 139 | 1.3.6.2 | SUMINISTRO E INST. DE TEE PVC C-10 110x110 MM | 2d | 2022-04-18 | 2022-04-19 | 138SS | 129d | 0d | start no earlier than 2021-03-01 | CEMENTO PORTLAND TIPO MS. [765.5%]; LUBRICANTE PARA TUBERIALUBRICANTE PARA TUBERIA [26%]; OPERARIO [169.8%]; OFICIAL [7.3%]; PEON [110.4%]; VIBRADOR DE CONCRETO 4 HP 1.25" [7.3%]; MEZCLADORA DE CONCRETO 11 P3 (23 HP) [3.6%]; PIEDRA CHANCADA 1/2" [69.9%]; ARENA GRUESA [55.7%]; AGUA [19.7%]; ANILLO DE JEBE P/TUB. PVC - UF DN 110MM [3900%]; TEE DE 110MM PVC [1300%] | 47.74h | 2,240.03 | 02.06.02 | 000000000000030 | 13 | 171.08 | 2224.04 |  |
| 140 | 1.3.6.3 | SUMINISTRO E INST. DE CODO 45° PVC C-10 110 MM | 1d | 2022-04-19 | 2022-04-20 | 139 | 129d | 0d | start no earlier than 2021-03-01 | CEMENTO PORTLAND TIPO MS. [46.3%]; LUBRICANTE PARA TUBERIALUBRICANTE PARA TUBERIA [4%]; OPERARIO [20.9%]; OFICIAL [0.9%]; PEON [23.5%]; VIBRADOR DE CONCRETO 4 HP 1.25" [0.9%]; MEZCLADORA DE CONCRETO 11 P3 (23 HP) [0.4%]; PIEDRA CHANCADA 1/2" [4.2%]; ARENA GRUESA [3.4%]; AGUA [1.2%]; CODO DE 110MM X 45° PVC [200%]; ANILLO DE JEBE P/TUB. PVC - UF DN 160MM [400%] | 3.73h | 215.46 | 02.06.03 | 000000000000032 |  | 101.52 | 203.04 | 10 |
| 141 | 1.3.6.4 | SUMINISTRO E INST. VALVULA COMPUERTA DE CONTROL DN 160MM, CON MARCO Y TAPA HIERRO DUCTIL | 2d | 2022-04-20 | 2022-04-22 | 140 | 129d | 0d | start no earlier than 2021-03-01 | CEMENTO PORTLAND TIPO MS. [852.6%]; LUBRICANTE PARA TUBERIALUBRICANTE PARA TUBERIA [12%]; OPERARIO [67.7%]; OFICIAL [72%]; PEON [216.2%]; VIBRADOR DE CONCRETO 4 HP 1.25" [7.7%]; MEZCLADORA DE CONCRETO 11 P3 (23 HP) [3.9%]; ACERO CORRUGADO fy = 4200 kg/cm2 GRADO 60 [2268%]; TUBERIA PVC-O UF PN8 D=160 mm NTP ISO 16422:2012. [900%]; PIEDRA CHANCADA 1/2" [72.5%]; ARENA GRUESA [59.2%]; AGUA [21%]; MARCO Y TAPA HDUCTIL P/ REGISTRO DE VALVULA [600%]; ANILLO DE JEBE P/TUB. PVC - UF DN 160MM [1200%]; VALVULA COMPUERTA HD DE 6" [600%] | 58.81h | 7,093.68 | 02.06.04 | 000000000000037 |  | 1042.84 | 6257.04 |  |
| 142 | 1.3.6.5 | SUMINISTRO E INST. VÁLVULA COMPUERTA DE CONTROL DN 110MM, CON MARCO Y TAPA HIERRO DUCTIL | 3d | 2022-04-20 | 2022-04-23 | 141SS | 129d | 0d | start no earlier than 2021-03-01 | CEMENTO PORTLAND TIPO MS. [1847.2%]; LUBRICANTE PARA TUBERIALUBRICANTE PARA TUBERIA [26%]; OPERARIO [97.8%]; OFICIAL [104.1%]; PEON [312.3%]; VIBRADOR DE CONCRETO 4 HP 1.25" [11.2%]; MEZCLADORA DE CONCRETO 11 P3 (23 HP) [5.6%]; ACERO CORRUGADO fy = 4200 kg/cm2 GRADO 60 [4914%]; TUBERIA PVC-O UF PN8 D=110 mm NTP ISO 16422:2012. [1950%]; PIEDRA CHANCADA 1/2" [157%]; ARENA GRUESA [128.3%]; AGUA [45.5%]; MARCO Y TAPA HDUCTIL P/ REGISTRO DE VALVULA [1300%]; ANILLO DE JEBE P/TUB. PVC - UF DN 110MM [2600%]; VALVULA COMPUERTA HD DE 4" [1300%] | 127.41h | 11,736.79 | 02.06.05 | 000000000000038 | 13 | 781.89 | 10164.57 |  |
| 143 | 1.3.6.6 | SUMINISTRO E INST. DE GRIFO CONTRAINCENDIO DN 160 MM | 4d | 2022-04-23 | 2022-04-27 | 142 | 129d | 0d | start no earlier than 2021-03-01 | CEMENTO PORTLAND TIPO MS. [482.4%]; LUBRICANTE PARA TUBERIALUBRICANTE PARA TUBERIA [4%]; OPERARIO [102.1%]; OFICIAL [103.6%]; PEON [210.4%]; VIBRADOR DE CONCRETO 4 HP 1.25" [2.1%]; MEZCLADORA DE CONCRETO 11 P3 (23 HP) [1.1%]; ACERO CORRUGADO fy = 4200 kg/cm2 GRADO 60 [1596%]; TUBERIA PVC-O UF PN8 D=160 mm NTP ISO 16422:2012. [210%]; PIEDRA CHANCADA 1/2" [38.7%]; ARENA GRUESA [32.3%]; AGUA [11.5%]; MARCO Y TAPA HDUCTIL P/ REGISTRO DE VALVULA [200%]; ANILLO DE JEBE P/TUB. PVC - UF DN 160MM [600%]; TEE DE 160 X 110 MM PVC C-10 [200%]; VALVULA COMPUERTA HD DE 6" [200%]; GRIFO CONTRAINCENDIO HIERRO DUCTIL TIPO POSTE 2 BOCAS DN 160MM [200%] | 134.17h | 10,034.64 | 02.06.06 | 000000000000039 |  | 4068.6 | 8137.2 | 0.5 |
| 144 | 1.3.6.7 | SUMINISTRO E INST. DE GRIFO CONTRAINCENDIO DN 110 MM | 8d | 2022-04-27 | 2022-05-05 | 143 | 129d |  | start no earlier than 2021-03-01 | CEMENTO PORTLAND TIPO MS. [964.9%]; LUBRICANTE PARA TUBERIALUBRICANTE PARA TUBERIA [20%]; OPERARIO [102.1%]; OFICIAL [103.6%]; PEON [210.4%]; VIBRADOR DE CONCRETO 4 HP 1.25" [2.1%]; MEZCLADORA DE CONCRETO 11 P3 (23 HP) [1.1%]; ACERO CORRUGADO fy = 4200 kg/cm2 GRADO 60 [3192%]; TUBERIA PVC-O UF PN8 D=110 mm NTP ISO 16422:2012. [420%]; PIEDRA CHANCADA 1/2" [77.3%]; ARENA GRUESA [64.6%]; AGUA [23%]; MARCO Y TAPA HDUCTIL P/ REGISTRO DE VALVULA [400%]; ANILLO DE JEBE P/TUB. PVC - UF DN 110MM [1200%]; TEE DE 110MM PVC [400%]; VALVULA COMPUERTA HD DE 4" [400%]; GRIFO CONTRAINCENDIO HIERRO DUCTIL TIPO POSTE 2 BOCAS DN 110MM [400%] | 268.35h | 17,793.48 | 02.06.07 | 000000000000040 |  | 3698.85 | 14795.4 | 0.5 |
| 145 | 1.3.6.8 | SUMINISTRO E INST. DE CRUZ PVC C-10 160x160 MM | 1d | 2022-04-20 | 2022-04-21 | 140 | 142d | 0d | start no earlier than 2021-03-01 | CEMENTO PORTLAND TIPO MS. [103.8%]; LUBRICANTE PARA TUBERIALUBRICANTE PARA TUBERIA [4%]; OPERARIO [68.6%]; OFICIAL [2%]; PEON [41.2%]; VIBRADOR DE CONCRETO 4 HP 1.25" [2%]; MEZCLADORA DE CONCRETO 11 P3 (23 HP) [1%]; PIEDRA CHANCADA 1/2" [9.5%]; ARENA GRUESA [7.5%]; AGUA [2.7%]; ANILLO DE JEBE P/TUB. PVC - UF DN 160MM [600%]; CRUZ DE 160MM X 160MM PVC [200%] | 9.18h | 1,388.54 | 02.06.08 | 000000000000053 |  | 578.39 | 1156.78 |  |
| 146 | 1.3.6.9 | SUMINISTRO E INST. DE CRUZ PVC C-10 110x110 MM | 1d | 2022-04-21 | 2022-04-22 | 145 | 142d |  | start no earlier than 2021-03-01 | CEMENTO PORTLAND TIPO MS. [140.2%]; LUBRICANTE PARA TUBERIALUBRICANTE PARA TUBERIA [10%]; OPERARIO [127.7%]; OFICIAL [2.7%]; PEON [73.2%]; VIBRADOR DE CONCRETO 4 HP 1.25" [2.7%]; MEZCLADORA DE CONCRETO 11 P3 (23 HP) [1.3%]; PIEDRA CHANCADA 1/2" [12.8%]; ARENA GRUESA [10.2%]; AGUA [3.6%]; ANILLO DE JEBE P/TUB. PVC - UF DN 110MM [1500%]; CRUZ DE 110MM X 110MM PVC [500%] | 16.6h | 1,982.3 | 02.06.09 | 000000000000054 |  | 238.43 | 1192.15 |  |

| ID | WBS | Task | Duration | Start | Finish | Predecessors | Total slack | Free slack | Constraint | Resources | Work | Cost | Text1 | Text8 | Text2 | Text3 | Text4 | Text6 |
| --- | --- | --- | --- | --- | --- | --- | --- | --- | --- | --- | --- | --- | --- | --- | --- | --- | --- | --- |
| 147 | 1.3.7 | **CONEXIONES DOMICILIARIAS** | 77d | 2022-04-16 | 2022-07-01 |  | 65d |  |  |  | 360373h | 704,414.76 | 02.07 | 000000000000008 |  |  |  |  |
| 148 | 1.3.7.1 | EXCAV. MANUAL TN PARA CONEXIONES DOMICILIARIAS P/AGUA | 30d | 2022-04-16 | 2022-05-15 | 122SS | 65d | 0d | start no earlier than 2021-03-01 | PEON [148135%] | 355524h | 216,064.82 | 02.07.01 | 000000000000041 | 4444 | 46.72 | 207623.68 |  |
| 149 | 1.3.7.2 | REFINE Y NIVELACION EN TERRENO NORMAL | 30d | 2022-04-16 | 2022-05-15 | 148SS | 65d | 0d | start no earlier than 2021-03-01 | PEON [195.3%]; EXCAVADORA S/ORUGA 195-225 HP 3.0 Y3. [97.9%] | 703.52h | 32,200.84 | 02.07.02 | 000000000000042 | 4444 | 6.87 | 30530.28 | 350 |
| 150 | 1.3.7.3 | CAMA DE MATERIAL PROPIO P/TUBERIA E=0.10M | 20d | 2022-04-16 | 2022-05-05 | 149SS | 65d | 0d | start no earlier than 2021-03-01 | OFICIAL [98.8%]; PEON [197.5%]; AFIRMADO [83325%] | 474.03h | 59,707.68 | 02.07.03 | 000000000000043 | 4444 | 12.8 | 56883.2 | 100 |
| 151 | 1.3.7.4 | RELLENO Y COMPACTACION DE ZANJA CON MATERIAL PROPIO SELECCIONADO C/MAQ. HASTA 0.90 DE PROF./PROM. CON. DOM. | 22d | 2022-06-09 | 2022-07-01 | 152SS | 65d | 0d | start no earlier than 2021-03-01 | OFICIAL [98.7%]; PEON [395%]; COMPACTADORA VIBRATORIA TIPO PLANCHA 7 HP [98.7%]; ZARANDA [197.5%]; AGUA [22220%] | 1390.39h | 81,628.66 | 02.07.04 | 000000000000044 | 4444 | 17.57 | 78081.08 | 60 |
| 152 | 1.3.7.5 | PRUEBA HIDRÁULICA Y DESINFECCION EN CONEXION DOMICILIARIA | 15d | 2022-06-09 | 2022-06-24 | 153 | 65d | 0d | start no earlier than 2021-03-01 | OPERARIO [98.9%]; PEON [98.9%]; BOMBA PARA PRUEBA DE AGUA [98.9%]; HIPOCLORITO DE CALCIO AL 70% [2222%]; AGUA [35996.4%] | 355.96h | 11,781.94 | 02.07.05 | 000000000000045 | 4444 | 2.52 | 11198.88 | 300 |
| 153 | 1.3.7.6 | CONEXIÓN DOMICILIARIA LARGA DE RED DE AGUA POTABLE POTABLE DN 110MM PVC A DN 1/2" | 35d | 2022-05-05 | 2022-06-09 | 150 | 65d | 0d | start no earlier than 2021-03-01 | CEMENTO PORTLAND TIPO V [19800%]; CEMENTO PORTLAND TIPO MS. [6662.3%]; OPERARIO [201.9%]; OFICIAL [101.9%]; PEON [207.7%]; VIBRADOR DE CONCRETO 4 HP 1.25" [1.9%]; MEZCLADORA DE CONCRETO 11 P3 (23 HP) [1%]; TUBERÍA PVC AGUA C-10 1/2" [396000%]; TUBERIA PVC SAL D= 2" [396000%]; PIEDRA CHANCADA 1/2" [608.3%]; ARENA GRUESA [5236.7%]; AGUA [171.1%]; ABRAZADERA DE PVC 110MM [39600%]; CURVA PVC PARA AGUA DE 1/2" [39600%]; UNION PVC C-10 DE 1/2" [79200%]; MARCO y TAPA TERMOPLASTICA PARA CAJA DE CONEXION DOMICIL. DE AGUA [39600%]; CODO DE 90° SP PVC SAP P/AGUA DE 1/2" [79200%]; CORPORATION RT NIPLE TUERCA EMPAQUE 1/2" [39600%]; CAJA DE CONCRETO PARA MEDIDOR [39600%]; LOSA CON NICHO PARA MEDIDOR DE AGUA POTABLE 1/2" [39600%]; CINTA TEFLON [79200%]; MEDIDOR DE CHORRO MULTIPLE 1/2" PARA AGUA [39600%]; NIPLE PVC SAP A-10 1/2"X4" [39600%]; LLAVE DE PASO PVC 1/2" (INC.TUER-NIPLE) [79200%]; ANCLAJE DE SEGURIDAD [79200%]; AFERICION DE MEDIDORES [39600%] | 1440.33h | 260,245.36 | 02.07.06 | 000000000000046 | 396 | 484.6 | 191901.6 |  |
| 154 | 1.3.7.7 | CONEXIÓN DOMICILIARIA CORTA DE RED DE AGUA POTABLE POTABLE DN 160MM PVC A DN 1/2" | 7d | 2022-06-09 | 2022-06-16 | 153 | 82d | 0d | start no earlier than 2021-03-01 | CEMENTO PORTLAND TIPO V [1950%]; CEMENTO PORTLAND TIPO MS. [656.1%]; OPERARIO [196.6%]; OFICIAL [99.1%]; PEON [201.2%]; VIBRADOR DE CONCRETO 4 HP 1.25" [1.6%]; MEZCLADORA DE CONCRETO 11 P3 (23 HP) [0.8%]; TUBERÍA PVC AGUA C-10 1/2" [23400%]; TUBERIA PVC SAL D= 2" [23400%]; PIEDRA CHANCADA 1/2" [59.9%]; ARENA GRUESA [515.7%]; AGUA [16.9%]; ABRAZADERA DE PVC 160MM [3900%]; CURVA PVC PARA AGUA DE 1/2" [3900%]; UNION PVC C-10 DE 1/2" [7800%]; MARCO y TAPA TERMOPLASTICA PARA CAJA DE CONEXION DOMICIL. DE AGUA [3900%]; CODO DE 90° SP PVC SAP P/AGUA DE 1/2" [7800%]; CORPORATION RT NIPLE TUERCA EMPAQUE 1/2" [3900%]; CAJA DE CONCRETO PARA MEDIDOR [3900%]; LOSA CON NICHO PARA MEDIDOR DE AGUA POTABLE 1/2" [3900%]; CINTA TEFLON [7800%]; MEDIDOR DE CHORRO MULTIPLE 1/2" PARA AGUA [3900%]; NIPLE PVC SAP A-10 1/2"X4" [3900%]; LLAVE DE PASO PVC 1/2" (INC.TUER-NIPLE) [7800%]; ANCLAJE DE SEGURIDAD [7800%]; AFERICION DE MEDIDORES [3900%] | 279.55h | 26,652.21 | 02.07.07 | 000000000000047 | 39 | 500 | 19500 |  |
| 155 | 1.3.7.8 | CONEXIÓN DOMICILIARIA LARGA DE RED DE AGUA POTABLE POTABLE DN 160MM PVC A DN 1/2" | 5d | 2022-06-16 | 2022-06-21 | 154 | 82d |  | start no earlier than 2021-03-01 | CEMENTO PORTLAND TIPO V [1250%]; CEMENTO PORTLAND TIPO MS. [420.6%]; OPERARIO [201.6%]; OFICIAL [101.6%]; PEON [206.4%]; VIBRADOR DE CONCRETO 4 HP 1.25" [1.6%]; MEZCLADORA DE CONCRETO 11 P3 (23 HP) [0.8%]; TUBERÍA PVC AGUA C-10 1/2" [25000%]; TUBERIA PVC SAL D= 2" [25000%]; PIEDRA CHANCADA 1/2" [38.4%]; ARENA GRUESA [330.6%]; AGUA [10.8%]; ABRAZADERA DE PVC 110MM [2500%]; CURVA PVC PARA AGUA DE 1/2" [2500%]; UNION PVC C-10 DE 1/2" [5000%]; MARCO y TAPA TERMOPLASTICA PARA CAJA DE CONEXION DOMICIL. DE AGUA [2500%]; CODO DE 90° SP PVC SAP P/AGUA DE 1/2" [5000%]; CORPORATION RT NIPLE TUERCA EMPAQUE 1/2" [2500%]; CAJA DE CONCRETO PARA MEDIDOR [2500%]; LOSA CON NICHO PARA MEDIDOR DE AGUA POTABLE 1/2" [2500%]; CINTA TEFLON [5000%]; MEDIDOR DE CHORRO MULTIPLE 1/2" PARA AGUA [2500%]; NIPLE PVC SAP A-10 1/2"X4" [2500%]; LLAVE DE PASO PVC 1/2" (INC.TUER-NIPLE) [5000%]; ANCLAJE DE SEGURIDAD [5000%]; AFERICION DE MEDIDORES [2500%] | 204.8h | 16,133.25 | 02.07.08 | 000000000000048 | 25 | 512.18 | 12804.5 |  |
| 156 | 1.3.8 | **LIMPIEZA FINAL DE OBRA** | 7d | 2022-07-02 | 2022-07-08 |  | 65d |  |  |  | 55.72h | 6,785 | 02.08 | 000000000000009 |  |  |  |  |
| 157 | 1.3.8.1 | LIMPIEZA DE TERRENO | 7d | 2022-07-02 | 2022-07-08 | 151 | 65d |  | start no earlier than 2021-03-01 | PEON | 55.72h | 6,785 | 02.08.01 | 000000000000049 | 4378.19 | 1.4 | 6129.47 | 100 |
| 158 | 1.4 | **EDUCACION SANITARIA** | 1d | 2022-03-17 | 2022-03-18 |  | 175d |  |  |  | 4h | 26,295 | 03 | 000000000000010 |  |  |  |  |
| 159 | 1.4.1 | EDUCACION SANITARIA | 1d | 2022-03-17 | 2022-03-18 | 14 | 175d | 0d | start no earlier than 2021-03-01 | CAPACITADOR [50%]; SPOTS RADIALES Y COMUNICADOS [400%]; IMPRESION Y FOTOCOPIADO DE MANUALES [400%]; MATERIAL DIDACTICO PARA LOS TALLERES DE CAPACITACION [400%]; ELABORACION Y DIAGRAMA DE MATERIAL DE SENSIBILIZACION Y CAPACITACION [400%] | 4h | 26,295 | 03.01 | 000000000000050 |  | 11200 | 11200 |  |
| 160 | 1.5 | **MITIGACION Y CONTROL DEL MEDIO AMBIENTE** | 1d | 2022-03-18 | 2022-03-19 |  | 175d |  |  |  |  | 37,200 | 04 | 000000000000012 |  |  |  |  |
| 161 | 1.5.1 | MITIGACION AMBIENTE | 1d | 2022-03-18 | 2022-03-19 | 159 | 175d | 0d | start no earlier than 2021-03-01 | PROGRAMA DE MITIGACION [400%]; PROGRAMA DE MANEJO DE RESIDUOS SOLIDOS [400%]; PROGRAMA DE MONITOREO AMBIENTAL [400%]; PROGRAMA DE EDUCACION AMBIENTAL Y SENSIBILIZACION [400%] |  | 37,200 | 04.01 | 000000000000051 |  | 24800 | 24800 |  |
| 162 | 1.6 | **PLAN DE MONITOREO ARQUEOLOGICO** | 1d | 2022-03-19 | 2022-03-20 |  | 175d |  |  |  |  | 16,000 | 05 | 000000000000011 |  |  |  |  |
| 163 | 1.6.1 | PLAN DE MONITOREO ARQUEOLOGICO | 1d | 2022-03-19 | 2022-03-20 | 161 | 175d |  | start no earlier than 2021-03-01 | PLAN DE MONITOREO ARQUEOLOGICO [400%] |  | 16,000 | 05.01 | 000000000000052 |  | 16000 | 16000 |  |
| 164 | 1.7 | **PLAN PARA LA VIGILANCIA, PREVENCIÓN Y CONTROL DEL COVID-19 EN EL TRABAJO** | 180d | 2022-03-16 | 2022-09-11 |  | 0d |  |  |  |  | 155,769.96 | 06 |  |  |  |  |  |
| 165 | 1.7.1 | **ELABORACIÓN DE DOCUMENTOS** | 1d | 2022-03-16 | 2022-03-16 |  | 0d |  |  |  |  | 5,500 | 06.01 |  |  |  |  |  |
| 166 | 1.7.1.1 | ELABORACION DEL PLAN PARA VIGILANCIA, PREVENCION Y CONTROL DEL COVID-19 | 1d | 2022-03-16 | 2022-03-16 | 5SS | 0d |  |  |  |  | 5,500 | 06.01.01 |  |  |  |  |  |
| 167 | 1.7.2 | **TRABAJOS PRELIMINARES** | 180d | 2022-03-16 | 2022-09-11 |  | 0d |  |  |  |  | 10,971.56 | 06.02 |  |  |  |  |  |
| 168 | 1.7.2.1 | LIMPIEZA Y DESINFECCION EN OBRA | 180d | 2022-03-16 | 2022-09-11 | 166FS-1d | 0d |  |  |  |  | 9,471.56 | 06.02.01 |  |  |  |  |  |
| 169 | 1.7.2.2 | SENSIBILIZACION DE LA PREVENCION DEL CONTAGIO COVID-19 EN OBRA | 1d | 2022-03-16 | 2022-03-16 | 168SS | 0d |  |  |  |  | 1,500 | 06.02.02 |  |  |  |  |  |
| 170 | 1.7.3 | **IMPLEMENTOS DE PROTECCION** | 180d | 2022-03-16 | 2022-09-11 |  | 0d |  |  |  |  | 17,953.52 | 06.03 |  |  |  |  |  |
| 171 | 1.7.3.1 | MEDIDAS DE PROTECCION PERSONAL DE LA OBRA COVID-19 | 180d | 2022-03-16 | 2022-09-11 | 169SS | 0d |  |  |  |  | 17,953.52 | 06.03.01 |  |  |  |  |  |

| ID | WBS | Task | Type | Duration | Start | Finish | Predecessors | Total slack | Free slack | Cost | Text1 |
| --- | --- | --- | --- | --- | --- | --- | --- | --- | --- | --- | --- |
| 172 | 1.7.4 | **ACTIVIDADES A SER IMPLEMENTADAS AL INICIO** |  | 180d | 2022-03-16 | 2022-09-11 |  | 0d |  | 76,118 | 06.04 |
| 173 | 1.7.4.1 | EVALUACION DE DESCARTE |  | 180d | 2022-03-16 | 2022-09-11 | 171SS | 0d |  | 37,942 | 06.04.01 |
| 174 | 1.7.4.2 | IDENTIFICACION DE SINTOMATOLOGIA COVID-19 |  | 180d | 2022-03-16 | 2022-09-11 | 173SS | 0d |  | 976 | 06.04.02 |
| 175 | 1.7.4.3 | PANELES INFORMATIVOS COVID-19 |  | 1d | 2022-03-17 | 2022-03-17 | 169 | 177d | 0d | 1,600 | 06.04.03 |
| 176 | 1.7.4.4 | CAPACITACIÓN OBLIGATORIA SOBRE SEGURIDAD Y SALUD EN EL TRABAJO |  | 1d | 2022-03-18 | 2022-03-18 | 175 | 177d |  | 800 | 06.04.04 |
| 177 | 1.7.4.5 | SERVICIO DE TRASLADO DEL PERSONAL HASTA LA OBRA |  | 180d | 2022-03-16 | 2022-09-11 | 174SS | 0d |  | 32,000 | 06.04.05 |
| 178 | 1.7.4.6 | SERVICIO DE ALIMENTACION AL PERSONAL OBRERO |  | 180d | 2022-03-16 | 2022-09-11 | 177SS | 0d |  | 2,800 | 06.04.06 |
| 179 | 1.7.5 | **ACTIVIDADES A SER IMPLEMENTADAS DURANTE LA EJECUCIÓN Y CIERRE** |  | 110d | 2022-03-16 | 2022-07-03 |  | 70d |  | 27,681.5 | 06.05 |
| 180 | 1.7.5.1 | ZONA DE CONTROL PREVIO |  | 110d | 2022-03-16 | 2022-07-03 | 178SS | 70d | 0d | 3,774.75 | 06.05.01 |
| 181 | 1.7.5.2 | ZONA DE CONTROL DE DESINFECCIÓN |  | 110d | 2022-03-16 | 2022-07-03 | 180SS | 70d | 0d | 3,774.75 | 06.05.02 |
| 182 | 1.7.5.3 | ZONA DE CONTROL DE VESTUARIOS |  | 110d | 2022-03-16 | 2022-07-03 | 181SS | 70d | 0d | 5,033 | 06.05.03 |
| 183 | 1.7.5.4 | ZONA DE TRABAJO |  | 110d | 2022-03-16 | 2022-07-03 | 182SS | 70d |  | 15,099 | 06.05.04 |
| 184 | 1.7.6 | **MEDIDAS PREVENTIVAS DURANTE EL TRABAJO** |  | 180d | 2022-03-16 | 2022-09-11 |  | 0d |  | 6,902.14 | 06.06 |
| 185 | 1.7.6.1 | INSTALACIÓN DE DISPENSADOR DE AGUA PARA EL LAVADO DE MANOS |  | 1d | 2022-03-16 | 2022-03-16 | 169SS | 0d |  | 2,592.5 | 06.06.01 |
| 186 | 1.7.6.2 | LAVADO Y DESINFECCION DE MANOS (OBLIGATORIO) |  | 180d | 2022-03-16 | 2022-09-11 | 185SS | 0d |  | 1,698 | 06.06.02 |
| 187 | 1.7.6.3 | MANEJO DE RESIDUOS SÓLIDOS |  | 1d | 2022-03-17 | 2022-03-17 | 185 | 176d | 0d | 2,611.64 | 06.06.03 |
| 188 | 1.7.7 | **MEDIDAS PARA LA OPERACIÓN DE MAQUINARIAS PESADAS Y VEHICULOS LIGEROS** |  | 180d | 2022-03-16 | 2022-09-11 |  | 0d |  | 5,802 | 06.07 |
| 189 | 1.7.7.1 | EQUIPO DE LIMPIEZA Y DESINFECCIÓN |  | 1d | 2022-03-18 | 2022-03-18 | 187 | 176d | 0d | 2,508.48 | 06.07.01 |
| 190 | 1.7.7.2 | ZONA DE SEGUIMIENTO Y CONTROL DE LIMPIEZA Y DESINFECCIÓN DE MAQUINARIAS PESADAS Y VEHÍCULOS LIGEROS |  | 180d | 2022-03-16 | 2022-09-11 | 186SS | 0d |  | 3,293.52 | 06.07.02 |
| 191 | 1.7.8 | **EQUIPAMIENTO Y PERSONAL DE SEGURIDAD Y SALUD EN EL TRABAJO** |  | 180d | 2022-03-16 | 2022-09-11 |  | 0d |  | 4,841.24 | 06.08 |
| 192 | 1.7.8.1 | EQUIPAMIENTO PARA LA VIGILANCIA DE LA SALUD |  | 1d | 2022-03-19 | 2022-03-19 | 189 | 176d |  | 2,882.08 | 06.08.01 |
| 193 | 1.7.8.2 | EQUIPO DE PROTECCIÓN PARA EL PROFESIONAL DE SEGURIDAD Y SALUD |  | 180d | 2022-03-16 | 2022-09-11 | 190SS | 0d |  | 1,959.16 | 06.08.02 |
| 194 | 2 | Fin | milestone | 0d | 2022-06-23 | 2022-06-23 | 126FF | 80d |  |  |  |
